# CRONOGRAMA PROYECTO SNR MUNICIPIOS AJUSTE CARTAGO

Schedule from MS Project, 2025-03-17 to 2025-12-17, A marks actual dates.

## Calendars

- Estándar: Mon-Fri 09:00-13:00, 15:00-19:00; Sat-Sun off. Exceptions (off unless hours are given): 2025-04-17 to 2025-04-18 (festivo), 2025-05-01 (festivo), 2025-06-02 (festivo), 2025-08-07 (festivo), 2025-08-18 (festivo), 2025-10-13 (festivo), 2025-11-03 (festivo), 2025-11-17 (festivo), 2025-12-08 (festivo).

## Resources

| Resource |
| --- |
| SNR |
| SKAPHE |
| 82 libros |

## Schedule

| ID | WBS | Task | Type | Duration | Start | Finish | Predecessors | Complete | Remaining | Total slack | Free slack | Constraint | Resources | Work | Actual work | %Planeado | %Retraso | Text30 |
| --- | --- | --- | --- | --- | --- | --- | --- | --- | --- | --- | --- | --- | --- | --- | --- | --- | --- | --- |
| 1 | 1 | **CRONOGRAMA SNR MUNICIPIOS** |  | 187d | 2025-03-17 A | 2025-12-17 |  |  | 186.35d | 0d |  |  |  | 63184h | 221.74h | 13% | 13% |  |
| 2 | 1.1 | **Yopal** |  | 73d | 2025-03-18 A | 2025-07-02 |  | 4% | 70.01d | 113d |  |  | SNR | 2488h | 141.5h | 32% | 28% | G3 |
| 3 | 1.1.1 | Visita tecnica de reconocimieto | milestone | 0d | 2025-03-18 A | 2025-03-18 A |  | 100% |  |  |  | start no earlier than 2025-03-18 | SKAPHE |  |  | 100% | 0% |  |
| 4 | 1.1.2 | Entrega informe Visita Tecnica | milestone | 0d | 2025-04-02 A | 2025-04-02 A | 3, 144, 190, 264, 311, 425, 469 | 100% |  |  |  | start no earlier than 2025-03-31 | SKAPHE |  |  | 100% | 0% |  |
| 5 | 1.1.3 | **Saneamiento Ambiental Preventivo** |  | 13d | 2025-04-08 A | 2025-04-29 |  | 99% | 0d | 158d | 8d |  | SKAPHE | 48h | 48h | 62% | -37% |  |
| 6 | 1.1.3.1 | Actividades de saneamiento |  | 2d | 2025-04-08 A | 2025-04-09 A |  | 100% |  |  |  | start no earlier than 2025-04-09 | SKAPHE | 16h | 16h | 100% | 0% |  |
| 7 | 1.1.3.2 | Entregar de Informe Saneamiento Ambiental Preventivo | milestone | 0d | 2025-04-29 | 2025-04-29 |  |  |  | 158d |  | start no earlier than 2025-04-29 | SKAPHE |  |  | 0% | 0% |  |
| 8 | 1.1.4 | Alistamiento, Entrega y Embalaje |  | 4d | 2025-04-09 A | 2025-04-14 |  | 50% | 2d | 166d |  | finish no earlier than 2025-04-14 | SKAPHE | 32h | 16h | 100% | 50% |  |
| 9 | 1.1.5 | Cargue, Traslado y descargue |  | 1d | 2025-04-15 A | 2025-04-15 A | 8FS-1d | 100% |  |  |  |  | SKAPHE | 8h | 8h | 100% | 0% |  |
| 10 | 1.1.6 | **Proceso de Intervención en Conservación Documental-Primeros Auxilios** |  | 26d | 2025-04-24 | 2025-05-30 | 9 |  |  | 113d |  |  | SKAPHE | 616h |  | 0% | 0% |  |
| 11 | 1.1.6.1 | Primeros Auxilios, desencuadernación e historia clinica y proceso de cuarentena |  | 24d | 2025-04-24 | 2025-05-28 |  |  |  | 113d | 0d | start no earlier than 2025-04-24 | SKAPHE | 192h |  | 0% | 0% |  |
| 12 | 1.1.6.2 | **Realizar Entrega de libros** |  | 23d | 2025-04-28 | 2025-05-30 |  |  |  | 113d |  |  | SKAPHE | 216h |  | 0% | 0% |  |
| 13 | 1.1.6.2.1 | Entrega libros No 1 | milestone | 0d | 2025-04-28 | 2025-04-28 | 11SS+3d |  |  | 134d | 0d | start no earlier than 2025-04-21 | SKAPHE |  |  | 0% | 0% |  |
| 14 | 1.1.6.2.2 | Aprobación entrega No 1 |  | 2d | 2025-04-29 | 2025-04-30 | 13 |  |  | 134d | 21d |  | SNR | 16h |  | 0% | 0% |  |
| 15 | 1.1.6.2.3 | Entrega libros No 2 | milestone | 0d | 2025-05-28 | 2025-05-28 | 11 |  |  | 113d | 0d | start no earlier than 2025-04-29 | SKAPHE |  |  | 0% | 0% |  |
| 16 | 1.1.6.2.4 | Aprobación Entrega No 2 |  | 2d | 2025-05-29 | 2025-05-30 | 15 |  |  | 113d | 0d |  | SNR | 16h |  | 0% | 0% |  |
| 17 | 1.1.7 | **Procesos de Digitalizacion** |  | 7d | 2025-06-03 | 2025-06-11 | 11SS+1d |  |  | 113d | 4d |  | SKAPHE | 144h |  | 0% | 0% |  |
| 18 | 1.1.7.1 | Realizar actividades de digitalización |  | 5d | 2025-06-03 | 2025-06-09 | 14, 16 |  |  | 113d | 0d |  | SKAPHE | 40h |  | 0% | 0% |  |
| 19 | 1.1.7.2 | **Realizar entrega de libros** |  | 2d | 2025-06-09 | 2025-06-11 |  |  |  | 113d |  |  | SKAPHE | 48h |  | 0% | 0% |  |
| 20 | 1.1.7.2.1 | Entrega libros No 1 | milestone | 0d | 2025-06-09 | 2025-06-09 | 18 |  |  | 113d | 0d |  | SKAPHE |  |  | 0% | 0% |  |
| 21 | 1.1.7.2.2 | Aprobación entrega No 1 |  | 2d | 2025-06-10 | 2025-06-11 | 20 |  |  | 113d | 0d |  | SNR | 16h |  | 0% | 0% |  |
| 22 | 1.1.7.2.3 | Entrega libros No 2 | milestone | 0d | 2025-06-09 | 2025-06-09 | 18 |  |  | 124d | 0d |  | SKAPHE |  |  | 0% | 0% |  |
| 23 | 1.1.7.2.4 | Aprobación Entrega No 2 |  | 2d | 2025-06-10 | 2025-06-11 | 22 |  |  | 124d | 0d |  | SNR | 16h |  | 0% | 0% |  |
| 24 | 1.1.8 | **Proceso de Descripcion e Indexacion** |  | 5d | 2025-06-10 | 2025-06-16 | 17SS+1d |  |  | 116d | 0d |  | SKAPHE | 136h |  | 0% | 0% |  |
| 25 | 1.1.8.1 | Realizar actividades de descripción e indexación |  | 5d | 2025-06-10 | 2025-06-16 | 18 |  |  | 125d |  |  | SKAPHE | 40h |  | 0% | 0% |  |

Notes:
- 4: Entrega Informe
- 7: Entrega Informe
- 9: 43 libros
- 13: 5 libros
- 15: 38 libros
- 20: 5 libros
- 22: 38 libros

| ID | WBS | Task | Type | Duration | Start | Finish | Predecessors | Complete | Remaining | Total slack | Free slack | Constraint | Resources | Work | %Planeado | %Retraso | Text30 |
| --- | --- | --- | --- | --- | --- | --- | --- | --- | --- | --- | --- | --- | --- | --- | --- | --- | --- |
| 26 | 1.1.8.2 | **Realizar entrega de libros** |  | 3d | 2025-06-11 | 2025-06-16 |  |  |  | 114d |  |  | SKAPHE | 56h | 0% | 0% |  |
| 27 | 1.1.8.2.1 | Entrega libros No 1 | milestone | 0d | 2025-06-12 | 2025-06-12 | 21FS+1d |  |  | 113d | 0d |  | SKAPHE |  | 0% | 0% |  |
| 28 | 1.1.8.2.2 | Aprobación entrega No 1 |  | 2d | 2025-06-13 | 2025-06-16 | 27 |  |  | 113d | 0d |  | SNR | 16h | 0% | 0% |  |
| 29 | 1.1.8.2.3 | Entrega libros No 2 | milestone | 0d | 2025-06-11 | 2025-06-11 | 23 |  |  | 124d | 0d |  | SKAPHE |  | 0% | 0% |  |
| 30 | 1.1.8.2.4 | Aprobación Entrega No 2 |  | 2d | 2025-06-12 | 2025-06-13 | 29 |  |  | 124d | 0d |  | SNR | 16h | 0% | 0% |  |
| 31 | 1.1.9 | **Proceso de Realmacenamiento en Unidades de Conservacion** |  | 3d | 2025-06-13 | 2025-06-18 | 24SS+2d |  |  | 123d |  |  | SKAPHE | 56h | 0% | 0% |  |
| 32 | 1.1.9.1 | Entrega libros No 1 | milestone | 0d | 2025-06-16 | 2025-06-16 | 28 |  |  | 123d | 0d |  | SKAPHE |  | 0% | 0% |  |
| 33 | 1.1.9.2 | Aprobación entrega No 1 |  | 2d | 2025-06-17 | 2025-06-18 | 32 |  |  | 123d |  |  | SNR | 16h | 0% | 0% |  |
| 34 | 1.1.9.3 | Entrega libros No 2 | milestone | 0d | 2025-06-13 | 2025-06-13 | 30 |  |  | 124d | 0d |  | SKAPHE |  | 0% | 0% |  |
| 35 | 1.1.9.4 | Aprobación Entrega No 2 |  | 2d | 2025-06-16 | 2025-06-17 | 34 |  |  | 124d |  |  | SNR | 16h | 0% | 0% |  |
| 36 | 1.1.10 | **Proceso de discos duros** |  | 5d | 2025-06-13 | 2025-06-19 |  |  |  | 113d |  |  | SKAPHE | 88h | 0% | 0% |  |
| 37 | 1.1.10.1 | Copiado en DD |  | 2d | 2025-06-13 | 2025-06-16 | 24SS+3d |  |  | 113d | 0d | start no earlier than 2025-05-02 | SKAPHE | 16h | 0% | 0% |  |
| 38 | 1.1.10.2 | **Entrega de Discos duros** |  | 2d | 2025-06-17 | 2025-06-19 | 37 |  |  | 113d | 0d |  | SKAPHE | 32h | 0% | 0% |  |
| 39 | 1.1.10.2.1 | Entrega libros No 1 | milestone | 0d | 2025-06-17 | 2025-06-17 | 28FS+1d, 37FS+1d |  |  | 113d | 0d |  | SKAPHE |  | 0% | 0% |  |
| 40 | 1.1.10.2.2 | Aprobación entrega No 1 |  | 2d | 2025-06-18 | 2025-06-19 | 39 |  |  | 113d |  |  | SNR | 16h | 0% | 0% |  |
| 41 | 1.1.11 | Traslado de Libros del Antiguo Sistema Registral al Archivo Central |  | 1d | 2025-07-02 | 2025-07-02 | 38FS+8d |  |  | 113d | 0d |  | SKAPHE | 8h | 0% | 0% |  |
| 42 | 1.1.12 | Intervencion tecnica por Demanda /Prestmo de Unidades documentales en porceos de Digitalizacion |  | 24d | 2025-05-23 | 2025-06-27 | 41SF-3d |  |  | 117d |  | start no earlier than 2025-04-11 | SKAPHE | 192h | 0% | 0% |  |
| 43 | 1.1.13 | Control Calidad Tranversal procesos |  | 36d | 2025-03-18 | 2025-05-09 | 3 |  |  | 150d |  | start no earlier than 2025-03-18 | SKAPHE; SNR | 576h | 64% | 64% |  |
| 44 | 1.2 | **Cartago** |  | 186d | 2025-03-18 A | 2025-12-16 |  |  | 186d | 0d |  |  | SKAPHE; SNR | 21832h | 12% | 12% | G1 |
| 45 | 1.2.1 | Visita tecnica de reconocimieto | milestone | 0d | 2025-03-18 A | 2025-03-18 A |  | 100% |  |  |  | start no earlier than 2025-03-18 | SKAPHE |  | 100% | 0% |  |
| 46 | 1.2.2 | Entrega informe Visita Tecnica | milestone | 0d | 2025-04-02 A | 2025-04-02 A | 45 | 100% |  |  |  | start no earlier than 2025-03-31 | SKAPHE |  | 100% | 0% |  |
| 47 | 1.2.3 | **Saneamiento Ambiental Preventivo** |  | 14d | 2025-04-21 | 2025-05-12 |  |  |  | 11d |  |  | SKAPHE | 16h | 7% | 7% |  |
| 48 | 1.2.3.1 | Actividades de saneamiento |  | 1d | 2025-04-21 | 2025-04-21 |  |  |  | 11d | 1d | start no earlier than 2025-04-21 |  |  | 100% | 100% |  |
| 49 | 1.2.3.2 | Entrega de Informe Saneamiento Ambiental Preventivo | milestone | 0d | 2025-05-12 | 2025-05-12 | 5 |  |  | 150d |  | start no earlier than 2025-05-12 | SKAPHE |  | 0% | 0% |  |

Notes:
- 27: 5 libros
- 29: 38 libros
- 32: 5 libros
- 34: 38 libros
- 38: 43 libros
- 49: Entrega Informe

| ID | WBS | Task | Type | Duration | Start | Finish | Predecessors | Total slack | Free slack | Constraint | Resources | Work | %Planeado | %Retraso |
| --- | --- | --- | --- | --- | --- | --- | --- | --- | --- | --- | --- | --- | --- | --- |
| 50 | 1.2.4 | **Alistamiento, Entrega y Embalaje** |  | 14d | 2025-04-22 | 2025-05-12 | 48FS-1d |  |  |  | SKAPHE | 224h | 0% | 0% |
| 51 | 1.2.4.1 | Alistamiento No 1 |  | 7d | 2025-04-22 | 2025-04-30 |  | 10d | 0d | start no earlier than 2025-04-22 | SKAPHE | 56h | 0% | 0% |
| 52 | 1.2.4.2 | Alistamiento No 2 |  | 7d | 2025-05-02 | 2025-05-12 | 51 | 20d | 0d | finish no earlier than 2025-05-07 | SKAPHE | 56h | 0% | 0% |
| 53 | 1.2.5 | **Cargue, Traslado y descargue** |  | 8d | 2025-05-02 | 2025-05-13 |  | 10d | 1d |  | SKAPHE | 80h | 0% | 0% |
| 54 | 1.2.5.1 | Traslado 1 |  | 1d | 2025-05-02 | 2025-05-02 | 51 | 10d | 0d | start no earlier than 2025-04-18 | SKAPHE | 8h | 0% | 0% |
| 55 | 1.2.5.2 | Traslado 2 |  | 1d | 2025-05-13 | 2025-05-13 | 52 | 20d |  | start no earlier than 2025-05-08 | SKAPHE | 8h | 0% | 0% |
| 56 | 1.2.6 | **Proceso de Intervención en Conservación Documental-Primeros Auxilios** |  | 145d | 2025-05-05 | 2025-12-01 | 54 | 10d |  |  | SKAPHE | 5344h | 0% | 0% |
| 57 | 1.2.6.1 | Primeros Auxilios, desencuadernación e historia clinica |  | 145d | 2025-05-05 | 2025-12-01 |  | 10d | 9d | start no earlier than 2025-05-05 | SKAPHE | 1160h | 0% | 0% |
| 58 | 1.2.6.2 | **Entrega de Libros** |  | 134d | 2025-05-20 | 2025-12-01 |  | 5d |  |  | SKAPHE; SNR | 3024h | 0% | 0% |
| 59 | 1.2.6.2.1 | Entrega libros 1 | milestone | 0d | 2025-05-20 | 2025-05-20 | 57SS+2d | 5d | 0d | start no earlier than 2025-05-20 | SKAPHE |  | 0% | 0% |
| 60 | 1.2.6.2.2 | Aprobación Entrega 1 |  | 15d | 2025-05-20 | 2025-06-10 | 59 | 5d | 0d |  | SNR | 120h | 0% | 0% |
| 61 | 1.2.6.2.3 | Entrega libros 2 | milestone | 0d | 2025-06-19 | 2025-06-19 |  | 108d | 0d | start no earlier than 2025-06-19 | SKAPHE |  | 0% | 0% |
| 62 | 1.2.6.2.4 | Aprobación Entrega 2 |  | 15d | 2025-06-19 | 2025-07-09 | 61 | 108d |  |  | SNR | 120h | 0% | 0% |
| 63 | 1.2.6.2.5 | Entrega libros 3 | milestone | 0d | 2025-07-18 | 2025-07-18 |  | 72d | 0d | start no earlier than 2025-07-18 | SKAPHE |  | 0% | 0% |
| 64 | 1.2.6.2.6 | Aprobación Entrega 3 |  | 16d | 2025-07-18 | 2025-08-11 | 63 | 72d | 0d |  | SNR | 128h | 0% | 0% |
| 65 | 1.2.6.2.7 | Entrega libros 4 | milestone | 0d | 2025-08-22 | 2025-08-22 |  | 63d | 0d | start no earlier than 2025-08-22 | SKAPHE |  | 0% | 0% |
| 66 | 1.2.6.2.8 | Aprobación Entrega 4 |  | 16d | 2025-08-22 | 2025-09-12 | 65 | 63d | 20d |  | SNR | 128h | 0% | 0% |
| 67 | 1.2.6.2.9 | Entrega libros 5 | milestone | 0d | 2025-09-19 | 2025-09-19 |  | 33d | 0d | start no earlier than 2025-09-19 | SKAPHE |  | 0% | 0% |
| 68 | 1.2.6.2.10 | Aprobación Entrega 5 |  | 16d | 2025-09-19 | 2025-10-10 | 67 | 33d | 0d |  | SNR | 128h | 0% | 0% |
| 69 | 1.2.6.2.11 | Entrega libros 6 | milestone | 0d | 2025-10-21 | 2025-10-21 |  | 14d | 0d | start no earlier than 2025-10-21 | SKAPHE |  | 0% | 0% |
| 70 | 1.2.6.2.12 | Aprobación Entrega 6 |  | 16d | 2025-10-21 | 2025-11-12 | 69 | 14d | 0d |  | SNR | 128h | 0% | 0% |
| 71 | 1.2.6.2.13 | Entrega libros 7 | milestone | 0d | 2025-11-07 | 2025-11-07 |  | 4d | 0d | start no earlier than 2025-11-07 | SKAPHE |  | 0% | 0% |
| 72 | 1.2.6.2.14 | Aprobación Entrega 7 |  | 16d | 2025-11-07 | 2025-12-01 | 71 | 4d | 0d |  | SNR | 128h | 0% | 0% |
| 73 | 1.2.7 | **Procesos de Digitalizacion** |  | 111d | 2025-06-24 | 2025-12-03 | 57SS+1d | 4d |  |  | SKAPHE | 1888h | 0% | 0% |
| 74 | 1.2.7.1 | **Entrega de Libros** |  | 111d | 2025-06-24 | 2025-12-03 |  | 4d |  |  | SKAPHE | 1000h | 0% | 0% |
| 75 | 1.2.7.1.1 | Entrega libros 1 | milestone | 0d | 2025-06-24 | 2025-06-24 | 60FS+10d | 5d | 0d | start no earlier than 2025-06-12 | SKAPHE |  | 0% | 0% |
| 76 | 1.2.7.1.2 | Aprobación Entrega 1 | milestone | 2d | 2025-06-25 | 2025-06-26 | 75 | 5d | 0d |  | SNR | 16h | 0% | 0% |
| 77 | 1.2.7.1.3 | Entrega libros 2 | milestone | 0d | 2025-07-09 | 2025-07-09 | 76 | 93d | 0d | start no earlier than 2025-07-09 | SKAPHE |  | 0% | 0% |
| 78 | 1.2.7.1.4 | Aprobación Entrega 2 | milestone | 2d | 2025-07-09 | 2025-07-10 | 77 | 93d | 0d |  | SNR | 16h | 0% | 0% |
| 79 | 1.2.7.1.5 | Entrega libros 3 | milestone | 0d | 2025-08-11 | 2025-08-11 | 64 | 72d | 0d | start no earlier than 2025-08-08 | SKAPHE |  | 0% | 0% |
| 80 | 1.2.7.1.6 | Aprobación Entrega 3 | milestone | 2d | 2025-08-12 | 2025-08-13 | 79 | 72d | 0d |  | SNR | 16h | 0% | 0% |
| 81 | 1.2.7.1.7 | Entrega libros 4 | milestone | 0d | 2025-09-19 | 2025-09-19 | 66SF | 47d | 0d | start no earlier than 2025-09-19 | SKAPHE |  | 0% | 0% |
| 82 | 1.2.7.1.8 | Aprobación Entrega 4 |  | 2d | 2025-09-19 | 2025-09-22 | 81 | 47d | 0d | start no earlier than 2024-09-12 | SNR | 16h | 0% | 0% |
| 83 | 1.2.7.1.9 | Entrega libros 5 | milestone | 0d | 2025-10-10 | 2025-10-10 | 68 | 33d | 0d | start no earlier than 2025-10-10 | SKAPHE |  | 0% | 0% |
| 84 | 1.2.7.1.10 | Aprobación Entrega 5 | milestone | 2d | 2025-10-14 | 2025-10-15 | 83 | 33d | 0d |  | SNR | 16h | 0% | 0% |
| 85 | 1.2.7.1.11 | Entrega libros 6 | milestone | 0d | 2025-11-12 | 2025-11-12 | 70 | 14d | 0d | start no earlier than 2025-11-11 | SKAPHE |  | 0% | 0% |
| 86 | 1.2.7.1.12 | Aprobación Entrega 6 | milestone | 2d | 2025-11-13 | 2025-11-14 | 85 | 14d | 0d |  | SNR | 16h | 0% | 0% |
| 87 | 1.2.7.1.13 | Entrega libros 7 | milestone | 0d | 2025-12-01 | 2025-12-01 | 72 | 4d | 0d |  | SKAPHE |  | 0% | 0% |
| 88 | 1.2.7.1.14 | Aprobación Entrega 7 | milestone | 2d | 2025-12-02 | 2025-12-03 | 87 | 4d | 0d |  | SNR | 16h | 0% | 0% |

Notes:
- 51: 300 libros
- 52: 423 libros
- 54: 300
- 55: 423
- 59: 118 libros
- 61: 48 libros
- 63: 67 libros
- 65: 170 libros
- 67: 28 libros
- 69: 232 libros
- 71: 60 libros
- 75: 118 libros
- 77: 48 libros
- 79: 67 libros
- 81: 170 libros
- 83: 28 libros
- 85: 232 libros
- 87: 60 libros

| ID | WBS | Task | Type | Duration | Start | Finish | Predecessors | Total slack | Free slack | Constraint | Resources | Work | %Planeado | %Retraso |
| --- | --- | --- | --- | --- | --- | --- | --- | --- | --- | --- | --- | --- | --- | --- |
| 89 | 1.2.8 | **Proceso de Descripcion e Indexacion** |  | 114d | 2025-06-25 | 2025-12-09 |  | 5d |  |  | SKAPHE | 2824h | 0% | 0% |
| 90 | 1.2.8.1 | Realizar actividades de descripción e indexación |  | 112d | 2025-06-27 | 2025-12-09 | 76 | 5d |  | start no earlier than 2025-05-06 | SKAPHE | 896h | 0% | 0% |
| 91 | 1.2.8.2 | **Entrega de libros** |  | 113d | 2025-06-25 | 2025-12-05 |  | 4d |  |  | SKAPHE | 1016h | 0% | 0% |
| 92 | 1.2.8.2.1 | Entrega libros 1 | milestone | 0d | 2025-06-25 | 2025-06-25 | 76SF | 11d | 0d |  | SKAPHE |  | 0% | 0% |
| 93 | 1.2.8.2.2 | Aprobación Entrega 1 |  | 2d | 2025-06-25 | 2025-06-26 | 92 | 11d | 0d |  | SNR | 16h | 0% | 0% |
| 94 | 1.2.8.2.3 | Entrega libros 2 | milestone | 0d | 2025-07-10 | 2025-07-10 | 78 | 93d | 0d |  | SKAPHE |  | 0% | 0% |
| 95 | 1.2.8.2.4 | Aprobación Entrega 2 |  | 2d | 2025-07-11 | 2025-07-14 | 94 | 93d | 0d |  | SNR | 16h | 0% | 0% |
| 96 | 1.2.8.2.5 | Entrega libros 3 | milestone | 0d | 2025-08-13 | 2025-08-13 | 80 | 72d | 0d |  | SKAPHE |  | 0% | 0% |
| 97 | 1.2.8.2.6 | Aprobación Entrega 3 |  | 2d | 2025-08-14 | 2025-08-15 | 96 | 72d | 0d |  | SNR | 16h | 0% | 0% |
| 98 | 1.2.8.2.7 | Entrega libros 4 | milestone | 0d | 2025-09-22 | 2025-09-22 | 82 | 47d | 0d |  | SKAPHE |  | 0% | 0% |
| 99 | 1.2.8.2.8 | Aprobación Entrega 4 |  | 2d | 2025-09-23 | 2025-09-24 | 98 | 47d | 0d |  | SNR | 16h | 0% | 0% |
| 100 | 1.2.8.2.9 | Entrega libros 5 | milestone | 0d | 2025-10-15 | 2025-10-15 | 84 | 33d | 0d |  | SKAPHE |  | 0% | 0% |
| 101 | 1.2.8.2.10 | Aprobación Entrega 5 |  | 2d | 2025-10-16 | 2025-10-17 | 100 | 33d | 0d |  | SNR | 16h | 0% | 0% |
| 102 | 1.2.8.2.11 | Entrega libros 6 | milestone | 0d | 2025-11-14 | 2025-11-14 | 86 | 14d | 0d |  | SKAPHE |  | 0% | 0% |
| 103 | 1.2.8.2.12 | Aprobación Entrega 6 |  | 2d | 2025-11-18 | 2025-11-19 | 102 | 14d | 0d |  | SNR | 16h | 0% | 0% |
| 104 | 1.2.8.2.13 | Entrega libros 7 | milestone | 0d | 2025-12-03 | 2025-12-03 | 88 | 4d | 0d |  | SKAPHE |  | 0% | 0% |
| 105 | 1.2.8.2.14 | Aprobación Entrega 7 |  | 2d | 2025-12-04 | 2025-12-05 | 104 | 4d | 0d |  | SNR | 16h | 0% | 0% |
| 106 | 1.2.9 | **Proceso de Realmacenamiento en Unidades de Conservacion** |  | 113d | 2025-06-26 | 2025-12-10 |  | 4d |  |  | SKAPHE | 2768h | 0% | 0% |
| 107 | 1.2.9.1 | Realizar actividades de realmacenamiento |  | 106d | 2025-06-27 | 2025-11-28 | 93 | 11d |  | start no earlier than 2025-06-09 | SKAPHE | 848h | 0% | 0% |
| 108 | 1.2.9.2 | **Entrega de libros** |  | 113d | 2025-06-26 | 2025-12-10 |  | 4d |  |  | SKAPHE | 1016h | 0% | 0% |
| 109 | 1.2.9.2.1 | Entrega libros 1 | milestone | 0d | 2025-06-26 | 2025-06-26 | 93 | 103d | 0d |  | SKAPHE |  | 0% | 0% |
| 110 | 1.2.9.2.2 | Aprobación Entrega 1 |  | 2d | 2025-06-27 | 2025-06-30 | 109 | 103d | 0d |  | SNR | 16h | 0% | 0% |
| 111 | 1.2.9.2.3 | Entrega libros 2 | milestone | 0d | 2025-07-14 | 2025-07-14 | 95, 110 | 93d | 0d |  | SKAPHE |  | 0% | 0% |
| 112 | 1.2.9.2.4 | Aprobación Entrega 2 |  | 2d | 2025-07-15 | 2025-07-16 | 111 | 93d | 21d |  | SNR | 16h | 0% | 0% |
| 113 | 1.2.9.2.5 | Entrega libros 3 | milestone | 0d | 2025-08-15 | 2025-08-15 | 97, 112 | 72d | 0d |  | SKAPHE |  | 0% | 0% |
| 114 | 1.2.9.2.6 | Aprobación Entrega 3 |  | 2d | 2025-08-19 | 2025-08-20 | 113 | 72d | 25d |  | SNR | 16h | 0% | 0% |
| 115 | 1.2.9.2.7 | Entrega libros 4 | milestone | 0d | 2025-09-24 | 2025-09-24 | 99, 114 | 47d | 0d |  | SKAPHE |  | 0% | 0% |
| 116 | 1.2.9.2.8 | Aprobación Entrega 4 |  | 2d | 2025-09-25 | 2025-09-26 | 115 | 47d | 14d |  | SNR | 16h | 0% | 0% |
| 117 | 1.2.9.2.9 | Entrega libros 5 | milestone | 0d | 2025-10-17 | 2025-10-17 | 101, 116 | 33d | 0d |  | SKAPHE |  | 0% | 0% |
| 118 | 1.2.9.2.10 | Aprobación Entrega 5 |  | 2d | 2025-10-20 | 2025-10-21 | 117 | 33d | 19d |  | SNR | 16h | 0% | 0% |
| 119 | 1.2.9.2.11 | Entrega libros 6 | milestone | 0d | 2025-11-19 | 2025-11-19 | 103, 118 | 14d | 0d |  | SKAPHE |  | 0% | 0% |
| 120 | 1.2.9.2.12 | Aprobación Entrega 6 |  | 2d | 2025-11-20 | 2025-11-21 | 119 | 14d | 10d |  | SNR | 16h | 0% | 0% |
| 121 | 1.2.9.2.13 | Entrega libros 7 | milestone | 0d | 2025-12-05 | 2025-12-05 | 105, 120 | 4d | 0d |  | SKAPHE |  | 0% | 0% |
| 122 | 1.2.9.2.14 | Aprobación Entrega 7 |  | 2d | 2025-12-09 | 2025-12-10 | 121 | 4d |  |  | SNR | 16h | 0% | 0% |

Notes:
- 92: 118 libros
- 94: 48 libros
- 96: 67 libros
- 98: 170 libros
- 100: 28 libros
- 102: 232 libros
- 104: 60 libros
- 109: 118 libros
- 111: 48 libros
- 113: 67 libros
- 115: 170 libros
- 117: 28 libros
- 119: 232 libros
- 121: 60 libros

| ID | WBS | Task | Type | Duration | Start | Finish | Predecessors | Complete | Remaining | Total slack | Free slack | Constraint | Resources | Work | Actual work | %Planeado | %Retraso | Text30 |
| --- | --- | --- | --- | --- | --- | --- | --- | --- | --- | --- | --- | --- | --- | --- | --- | --- | --- | --- |
| 123 | 1.2.10 | **Proceso discos duros** |  | 129d | 2025-06-09 | 2025-12-12 |  |  |  | 2d |  |  | SKAPHE | 3072h |  | 0% | 0% |  |
| 124 | 1.2.10.1 | Realizar copiado de discos duros |  | 128d | 2025-06-09 | 2025-12-11 |  |  |  | 3d |  | start no earlier than 2025-06-09 | SKAPHE | 1024h |  | 0% | 0% |  |
| 125 | 1.2.10.2 | **Entrega de libros en DD** |  | 113d | 2025-06-30 | 2025-12-12 | 110 |  |  | 2d |  |  | SKAPHE | 1016h |  | 0% | 0% |  |
| 126 | 1.2.10.2.1 | Entrega libros 1 | milestone | 0d | 2025-06-30 | 2025-06-30 | 124SS+1d |  |  | 113d | 0d | start no earlier than 2025-06-09 | SKAPHE |  |  | 0% | 0% |  |
| 127 | 1.2.10.2.2 | Aprobación Entrega 1 |  | 2d | 2025-07-01 | 2025-07-02 | 126 |  |  | 113d |  |  | SNR | 16h |  | 0% | 0% |  |
| 128 | 1.2.10.2.3 | Entrega libros 2 | milestone | 0d | 2025-07-09 | 2025-07-09 |  |  |  | 107d | 0d | start no earlier than 2025-07-09 | SKAPHE |  |  | 0% | 0% |  |
| 129 | 1.2.10.2.4 | Aprobación Entrega 2 |  | 2d | 2025-07-09 | 2025-07-10 | 128 |  |  | 107d |  |  | SNR | 16h |  | 0% | 0% |  |
| 130 | 1.2.10.2.5 | Entrega libros 3 | milestone | 0d | 2025-08-11 | 2025-08-11 |  |  |  | 85d | 0d | start no earlier than 2025-08-11 | SKAPHE |  |  | 0% | 0% |  |
| 131 | 1.2.10.2.6 | Aprobación Entrega 3 |  | 2d | 2025-08-11 | 2025-08-12 | 130 |  |  | 85d |  |  | SNR | 16h |  | 0% | 0% |  |
| 132 | 1.2.10.2.7 | Entrega libros 4 | milestone | 0d | 2025-09-17 | 2025-09-17 |  |  |  | 59d | 0d | start no earlier than 2025-09-17 | SKAPHE |  |  | 0% | 0% |  |
| 133 | 1.2.10.2.8 | Aprobación Entrega 4 |  | 2d | 2025-09-17 | 2025-09-18 | 132 |  |  | 59d |  |  | SNR | 16h |  | 0% | 0% |  |
| 134 | 1.2.10.2.9 | Entrega libros 5 | milestone | 0d | 2025-10-08 | 2025-10-08 |  |  |  | 44d | 0d | start no earlier than 2025-10-08 | SKAPHE |  |  | 0% | 0% |  |
| 135 | 1.2.10.2.10 | Aprobación Entrega 5 |  | 2d | 2025-10-08 | 2025-10-09 | 134 |  |  | 44d |  |  | SNR | 16h |  | 0% | 0% |  |
| 136 | 1.2.10.2.11 | Entrega libros 6 | milestone | 0d | 2025-11-21 | 2025-11-21 |  |  |  | 15d | 0d | start no earlier than 2025-11-21 | SKAPHE |  |  | 0% | 0% |  |
| 137 | 1.2.10.2.12 | Aprobación Entrega 6 |  | 2d | 2025-11-21 | 2025-11-24 | 136 |  |  | 15d |  |  | SNR | 16h |  | 0% | 0% |  |
| 138 | 1.2.10.2.13 | Entrega libros 7 | milestone | 0d | 2025-12-11 | 2025-12-11 |  |  |  | 2d | 0d | start no earlier than 2025-12-11 | SKAPHE |  |  | 0% | 0% |  |
| 139 | 1.2.10.2.14 | Aprobación Entrega 7 |  | 2d | 2025-12-11 | 2025-12-12 | 138 |  |  | 2d |  |  | SNR | 16h |  | 0% | 0% |  |
| 140 | 1.2.11 | Traslado de Libros del Antiguo Sistema Registral al Archivo Central |  | 2d | 2025-12-15 | 2025-12-16 | 124FS-2d |  |  | 0d |  | start no earlier than 2025-12-15 | SKAPHE | 16h |  | 0% | 0% |  |
| 141 | 1.2.12 | Intervencion tecnica por Demanda /Prestamo de Unidades documentales en porceos de Digitalizacion |  | 163d | 2025-04-21 | 2025-12-15 | 9FS-1d |  |  | 1d |  | start no earlier than 2025-04-18 | SKAPHE | 1304h |  | 1% | 1% |  |
| 142 | 1.2.13 | Control Calidad Tranversal procesos |  | 165d | 2025-04-16 | 2025-12-16 |  |  |  | 0d |  | finish no earlier than 2025-12-16 | SKAPHE | 1320h |  | 1% | 1% |  |
| 143 | 1.3 | **Riohacha** |  | 64d | 2025-03-17 A | 2025-06-18 |  |  | 63.72d | 123d |  |  | SKAPHE | 4136h | 10.22h | 38% | 38% | G2 |
| 144 | 1.3.1 | Visita tecnica de reconocimieto |  | 1d | 2025-03-17 A | 2025-03-17 A |  | 100% |  |  |  | start no earlier than 2025-03-17 | SKAPHE | 8h | 8h | 100% | 0% |  |
| 145 | 1.3.2 | Entrega informe Visita Tecnica | milestone | 0d | 2025-04-02 A | 2025-04-02 A | 144 | 100% |  |  |  | start no earlier than 2025-03-31 | SKAPHE |  |  | 100% | 0% |  |
| 146 | 1.3.3 | **Saneamiento Ambiental Preventivo** |  | 13d | 2025-04-22 | 2025-05-12 |  |  |  | 31d |  |  | SKAPHE | 24h |  | 0% | 0% |  |
| 147 | 1.3.3.1 | Actividades de saneamiento |  | 1d | 2025-04-22 | 2025-04-22 |  |  |  | 31d | 1d | start no earlier than 2025-04-22 | SKAPHE | 8h |  | 0% | 0% |  |
| 148 | 1.3.3.2 | Entrega de Informe Saneamiento Ambiental Preventivo | milestone | 0d | 2025-05-12 | 2025-05-12 |  |  |  | 150d |  | start no earlier than 2025-05-12 | SKAPHE |  |  | 0% | 0% |  |
| 149 | 1.3.4 | Alistamiento, Entrega y Embalaje |  | 7d | 2025-04-24 | 2025-05-05 | 147 |  |  | 30d | 0d | start no earlier than 2025-04-24 | SKAPHE | 56h |  | 0% | 0% |  |
| 150 | 1.3.5 | Cargue, Traslado y descargue |  | 1d | 2025-05-06 | 2025-05-06 | 149 |  |  | 30d | 0d |  | SKAPHE | 8h |  | 0% | 0% |  |

Notes:
- 126: 118 libros
- 128: 48 libros
- 130: 67 libros
- 132: 170 libros
- 134: 28 libros
- 136: 232 libros
- 138: 60 libros
- 145: Entrega Informe
- 148: Entrega Informe
- 150: 43 libros

| ID | WBS | Task | Type | Duration | Start | Finish | Predecessors | Total slack | Free slack | Constraint | Resources | Work | %Planeado | %Retraso |
| --- | --- | --- | --- | --- | --- | --- | --- | --- | --- | --- | --- | --- | --- | --- |
| 151 | 1.3.6 | **Procesos de Conservacion a nivel de Primeros Auxilios** |  | 18d | 2025-05-07 | 2025-05-30 |  | 129d |  |  | SKAPHE | 320h | 0% | 0% |
| 152 | 1.3.6.1 | Primeros Auxilios, desencuadernación e historia clinica |  | 8d | 2025-05-07 | 2025-05-16 | 150 | 130d | 0d |  | SKAPHE | 64h | 0% | 0% |
| 153 | 1.3.6.2 | **Realizar entregas de libros** |  | 10d | 2025-05-16 | 2025-05-30 |  | 129d |  |  | SKAPHE | 112h | 0% | 0% |
| 154 | 1.3.6.2.1 | Entrega libros No 1 | milestone | 0d | 2025-05-16 | 2025-05-16 | 152 | 137d | 0d | start no earlier than 2025-05-12 | SKAPHE |  | 0% | 0% |
| 155 | 1.3.6.2.2 | Aprobación entrega No 1 |  | 2d | 2025-05-19 | 2025-05-20 | 154 | 137d | 0d |  | SNR | 16h | 0% | 0% |
| 156 | 1.3.6.2.3 | Entrega de libros No 2 | milestone | 0d | 2025-05-29 | 2025-05-29 | 152 | 127d | 0d | start no earlier than 2025-05-29 | SKAPHE |  | 0% | 0% |
| 157 | 1.3.6.2.4 | Aprobación entrega No 2 |  | 2d | 2025-05-29 | 2025-05-30 | 156 | 127d | 0d |  | SNR | 16h | 0% | 0% |
| 158 | 1.3.7 | **Proceso de Digitalizacion** |  | 20d | 2025-05-12 | 2025-06-09 | 152SS+3d | 130d | 0d |  | SKAPHE | 432h | 0% | 0% |
| 159 | 1.3.7.1 | Realizar actividades de digitalización |  | 20d | 2025-05-12 | 2025-06-09 |  | 130d |  |  | SKAPHE | 160h | 0% | 0% |
| 160 | 1.3.7.2 | **Realizar Entrega de libros** |  | 10d | 2025-05-20 | 2025-06-04 |  | 129d |  |  | SKAPHE | 112h | 0% | 0% |
| 161 | 1.3.7.2.1 | Entrega libros No 1 | milestone | 0d | 2025-05-20 | 2025-05-20 | 155 | 137d | 0d |  | SKAPHE |  | 0% | 0% |
| 162 | 1.3.7.2.2 | Aprobación entrega No 1 |  | 2d | 2025-05-21 | 2025-05-22 | 161 | 137d | 0d |  | SNR | 16h | 0% | 0% |
| 163 | 1.3.7.2.3 | Entrega de libros No 2 | milestone | 0d | 2025-05-30 | 2025-05-30 | 157 | 127d | 0d |  | SKAPHE |  | 0% | 0% |
| 164 | 1.3.7.2.4 | Aprobación entrega No 2 |  | 2d | 2025-06-03 | 2025-06-04 | 163 | 127d | 0d |  | SNR | 16h | 0% | 0% |
| 165 | 1.3.8 | **Proceso de Descripcion e Indexacion** |  | 22d | 2025-05-13 | 2025-06-12 | 158SS+1d | 127d | 0d |  | SKAPHE | 464h | 0% | 0% |
| 166 | 1.3.8.1 | Realizar actividades de descripción e indexación |  | 20d | 2025-05-13 | 2025-06-10 |  | 129d |  | start no earlier than 2025-05-09 | SKAPHE | 160h | 0% | 0% |
| 167 | 1.3.8.2 | **Realizar entrega de libros** |  | 12d | 2025-05-26 | 2025-06-12 |  | 127d |  |  | SKAPHE | 128h | 0% | 0% |
| 168 | 1.3.8.2.1 | Entrega de libros No 1 | milestone | 0d | 2025-05-26 | 2025-05-26 | 162FS+2d | 137d | 0d |  | SKAPHE |  | 0% | 0% |
| 169 | 1.3.8.2.2 | Aprobación entrega No 1 |  | 2d | 2025-05-27 | 2025-05-28 | 168 | 137d |  |  | SNR | 16h | 0% | 0% |
| 170 | 1.3.8.2.3 | Entrega de libros No 2 | milestone | 0d | 2025-06-10 | 2025-06-10 | 164FS+4d | 127d | 0d | start no earlier than 2025-06-06 | SKAPHE |  | 0% | 0% |
| 171 | 1.3.8.2.4 | Aprobación entrega No 2 |  | 2d | 2025-06-11 | 2025-06-12 | 170 | 127d |  |  | SNR | 16h | 0% | 0% |
| 172 | 1.3.9 | **Proceso de Realmacenamiento en Unidades de Conservacion** |  | 21d | 2025-05-20 | 2025-06-18 | 165SS+5d | 123d |  |  | SKAPHE | 448h | 0% | 0% |
| 173 | 1.3.9.1 | Realizar actividades de realmacenamiento |  | 17d | 2025-05-20 | 2025-06-12 |  | 123d | 0d |  | SKAPHE | 136h | 0% | 0% |
| 174 | 1.3.9.2 | **Realizar entrega de libros** |  | 14d | 2025-05-28 | 2025-06-18 |  | 123d |  |  | SKAPHE | 144h | 0% | 0% |
| 175 | 1.3.9.2.1 | Entrega libros No 1 | milestone | 0d | 2025-05-28 | 2025-05-28 | 173SS+7d | 135d | 0d | start no earlier than 2025-05-15 | SKAPHE |  | 0% | 0% |
| 176 | 1.3.9.2.2 | Aprobación entrega No 1 |  | 2d | 2025-05-29 | 2025-05-30 | 175 | 135d |  |  | SNR | 16h | 0% | 0% |
| 177 | 1.3.9.2.3 | Entrega de libros No 2 | milestone | 0d | 2025-06-16 | 2025-06-16 | 173FS+2d | 123d | 0d |  | SKAPHE |  | 0% | 0% |
| 178 | 1.3.9.2.4 | Aprobación entrega No 2 |  | 2d | 2025-06-17 | 2025-06-18 | 177 | 123d |  |  | SNR | 16h | 0% | 0% |

Notes:
- 154: 100 libros
- 156: 135 libros
- 161: 100 libros
- 163: 135 libros
- 168: 100 libros
- 170: 135 libros
- 175: 100 libros
- 177: 135 libros

| ID | WBS | Task | Type | Duration | Start | Finish | Predecessors | Complete | Remaining | Total slack | Free slack | Constraint | Resources | Work | Actual work | %Planeado | %Retraso | Text30 |
| --- | --- | --- | --- | --- | --- | --- | --- | --- | --- | --- | --- | --- | --- | --- | --- | --- | --- | --- |
| 179 | 1.3.10 | **Proceso Discos Duros** |  | 18d | 2025-05-23 | 2025-06-18 |  |  |  | 123d |  |  | SKAPHE | 392h |  | 0% | 0% |  |
| 180 | 1.3.10.1 | Realizar copiado de DD |  | 13d | 2025-05-23 | 2025-06-11 | 165SS+8d |  |  | 123d | 0d |  | SKAPHE | 104h |  | 0% | 0% |  |
| 181 | 1.3.10.2 | **Realizar entrega de DD** |  | 14d | 2025-05-28 | 2025-06-18 |  |  |  | 123d |  |  | SKAPHE | 144h |  | 0% | 0% |  |
| 182 | 1.3.10.2.1 | Entrega libros No 1 | milestone | 0d | 2025-05-28 | 2025-05-28 | 180SS+4d |  |  | 135d | 0d |  | SKAPHE |  |  | 0% | 0% |  |
| 183 | 1.3.10.2.2 | Aprobación entrega No 1 |  | 2d | 2025-05-29 | 2025-05-30 | 182 |  |  | 135d |  |  | SNR | 16h |  | 0% | 0% |  |
| 184 | 1.3.10.2.3 | Entrega de libros No 2 | milestone | 0d | 2025-06-16 | 2025-06-16 | 180FS+3d |  |  | 123d | 0d |  | SKAPHE |  |  | 0% | 0% |  |
| 185 | 1.3.10.2.4 | Aprobación entrega No 2 |  | 2d | 2025-06-17 | 2025-06-18 | 184 |  |  | 123d |  |  | SNR | 16h |  | 0% | 0% |  |
| 186 | 1.3.11 | Traslado de Libros del Antiguo Sistema Registral al Archivo Central |  | 1d | 2025-06-17 | 2025-06-17 | 180FS+3d |  |  | 124d |  |  | SKAPHE | 8h |  | 0% | 0% |  |
| 187 | 1.3.12 | Intervencion tecnica por Demanda /Prestamo de Unidades documentales en porceos de Digitalizacion |  | 61d | 2025-03-17 | 2025-06-13 |  |  |  | 126d | 0d | start no earlier than 2025-03-17 | SKAPHE | 488h |  | 39% | 39% |  |
| 188 | 1.3.13 | Control Calidad Tranversal procesos |  | 61d | 2025-03-17 | 2025-06-13 | 187FF |  |  | 126d |  | start no earlier than 2025-03-17 | SKAPHE; SNR | 976h |  | 39% | 39% |  |
| 189 | 1.4 | **Sabana Larga** |  | 136d | 2025-03-18 A | 2025-10-01 |  |  | 135.65d | 50d |  |  | SKAPHE | 5808h | 10.8h | 17% | 17% | G2 |
| 190 | 1.4.1 | Visita tecnica de reconocimieto |  | 1d | 2025-03-18 A | 2025-03-18 A |  | 100% |  |  |  | start no earlier than 2025-03-18 | SKAPHE | 8h | 8h | 100% | 0% |  |
| 191 | 1.4.2 | Entrega informe Visita Tecnica | milestone | 0d | 2025-04-02 A | 2025-04-02 A | 190 | 100% |  |  |  | start no earlier than 2025-03-31 | SKAPHE |  |  | 100% | 0% |  |
| 192 | 1.4.3 | **Saneamiento Ambiental Preventivo** |  | 19d | 2025-05-06 | 2025-06-03 |  |  |  | 30d |  |  | SKAPHE | 136h |  | 0% | 0% |  |
| 193 | 1.4.3.1 | Realizar actividades de saneamiento ambiental |  | 1d | 2025-05-06 | 2025-05-06 | 150FS-1d |  |  | 30d | 0d | start no earlier than 2025-05-06 | SKAPHE | 8h |  | 0% | 0% |  |
| 194 | 1.4.3.2 | Entrega de Informe Saneamiento Ambiental Preventivo | milestone | 0d | 2025-06-03 | 2025-06-03 |  |  |  | 135d |  | start no earlier than 2025-06-03 | SKAPHE |  |  | 0% | 0% |  |
| 195 | 1.4.4 | Alistamiento, Entrega y Embalaje |  | 12d | 2025-05-07 | 2025-05-22 | 193 |  |  | 30d | 0d | start no earlier than 2025-05-07 | SKAPHE | 96h |  | 0% | 0% |  |
| 196 | 1.4.5 | Cargue, Traslado y descargue |  | 1d | 2025-05-23 | 2025-05-23 | 195 |  |  | 30d | 0d |  | SKAPHE | 8h |  | 0% | 0% |  |
| 197 | 1.4.6 | Entrega de informe | milestone | 0d | 2025-06-03 | 2025-06-03 | 196 |  |  | 135d |  | start no earlier than 2025-06-03 | SKAPHE |  |  | 0% | 0% |  |
| 198 | 1.4.7 | **Proceso de Intervención en Conservación Documental-Primeros Auxilios** |  | 32d | 2025-05-26 | 2025-07-09 |  |  |  | 51d |  |  | SKAPHE | 880h |  | 0% | 0% |  |
| 199 | 1.4.7.1 | Primeros Auxilios, desencuadernación e historia clinica |  | 30d | 2025-05-26 | 2025-07-07 | 196 |  |  | 51d | 0d | start no earlier than 2025-05-05 | SKAPHE | 240h |  | 0% | 0% |  |
| 200 | 1.4.7.2 | Actividades de conservación primeros auxilios |  | 30d | 2025-05-27 | 2025-07-08 |  |  |  | 109d |  | start no earlier than 2025-05-27 | SKAPHE | 240h |  | 0% | 0% |  |
| 201 | 1.4.7.3 | **Realizar entrega de libros** |  | 14d | 2025-06-19 | 2025-07-09 |  |  |  | 63d |  |  | SKAPHE | 144h |  | 0% | 0% |  |
| 202 | 1.4.7.3.1 | Entrega libros No 1 | milestone | 0d | 2025-06-19 | 2025-06-19 | 199SS+18d |  |  | 120d | 0d | start no earlier than 2025-06-04 | SKAPHE |  |  | 0% | 0% |  |
| 203 | 1.4.7.3.2 | Realizar aprobación entrega No 1 |  | 2d | 2025-06-20 | 2025-06-23 | 202 |  |  | 120d |  |  | SNR | 16h |  | 0% | 0% |  |
| 204 | 1.4.7.3.3 | Entrega libros No 2 | milestone | 0d | 2025-07-07 | 2025-07-07 | 199 |  |  | 51d | 0d | start no earlier than 2025-07-01 | SKAPHE |  |  | 0% | 0% |  |
| 205 | 1.4.7.3.4 | Realizar aprobación entrega No 2 |  | 2d | 2025-07-08 | 2025-07-09 | 204 |  |  | 51d | 0d |  | SNR | 16h |  | 0% | 0% |  |

Notes:
- 182: 100 libros
- 184: 135 libros
- 191: Entrega Informe
- 194: Entrega Informe
- 196: 348 libros
- 197: Entrega Informe
- 202: 170 libros
- 204: 178 libros

| ID | WBS | Task | Type | Duration | Start | Finish | Predecessors | Total slack | Free slack | Constraint | Resources | Work | %Planeado | %Retraso |
| --- | --- | --- | --- | --- | --- | --- | --- | --- | --- | --- | --- | --- | --- | --- |
| 206 | 1.4.8 | **Proceso de Digitalizacion** |  | 34d | 2025-07-10 | 2025-08-28 | 199SS+2d | 51d | 0d |  | SKAPHE | 696h | 0% | 0% |
| 207 | 1.4.8.1 | Actividades de digitalización |  | 32d | 2025-07-10 | 2025-08-26 | 205 | 51d | 0d | start no earlier than 2025-05-19 | SKAPHE | 256h | 0% | 0% |
| 208 | 1.4.8.2 | **Realizar entrega de libros** |  | 17d | 2025-08-01 | 2025-08-28 |  | 74d |  |  | SKAPHE | 168h | 0% | 0% |
| 209 | 1.4.8.2.1 | Entrega libros No 1 | milestone | 0d | 2025-08-01 | 2025-08-01 | 207SS+17d | 89d | 0d | start no earlier than 2025-06-09 | SKAPHE |  | 0% | 0% |
| 210 | 1.4.8.2.2 | Realizar aprobación entrega No 1 |  | 2d | 2025-08-04 | 2025-08-05 | 209 | 89d |  | finish no earlier than 2025-06-05 | SNR | 16h | 0% | 0% |
| 211 | 1.4.8.2.3 | Entrega libros No 2 | milestone | 0d | 2025-08-26 | 2025-08-26 | 207 | 74d | 0d | start no earlier than 2025-07-09 | SKAPHE |  | 0% | 0% |
| 212 | 1.4.8.2.4 | Realizar aprobación entrega No 2 |  | 2d | 2025-08-27 | 2025-08-28 | 211 | 74d |  | finish no earlier than 2025-07-02 | SNR | 16h | 0% | 0% |
| 213 | 1.4.9 | **Proceso de Descripcion e Indexacion** |  | 21d | 2025-07-30 | 2025-09-01 | 206SS+15d | 51d | 15d |  | SKAPHE | 384h | 0% | 0% |
| 214 | 1.4.9.1 | Actividades de descripción e indexación |  | 21d | 2025-07-31 | 2025-09-01 |  | 51d | 0d | start no earlier than 2025-05-21 | SKAPHE | 168h | 0% | 0% |
| 215 | 1.4.9.2 | **Realizar entrega de libros** |  | 2d | 2025-07-30 | 2025-08-01 |  | 91d |  |  | SKAPHE | 48h | 0% | 0% |
| 216 | 1.4.9.2.1 | Entrega libros No 1 | milestone | 0d | 2025-07-30 | 2025-07-30 |  | 91d | 0d | start no earlier than 2025-06-23 | SKAPHE |  | 0% | 0% |
| 217 | 1.4.9.2.2 | Realizar aprobación entrega No 1 |  | 2d | 2025-07-31 | 2025-08-01 | 216 | 91d |  | finish no earlier than 2025-06-05 | SNR | 16h | 0% | 0% |
| 218 | 1.4.9.2.3 | Entrega libros No 2 | milestone | 0d | 2025-07-30 | 2025-07-30 |  | 91d | 0d | start no earlier than 2025-07-11 | SKAPHE |  | 0% | 0% |
| 219 | 1.4.9.2.4 | Realizar aprobación entrega No 2 |  | 2d | 2025-07-31 | 2025-08-01 | 218 | 91d |  | finish no earlier than 2025-07-02 | SNR | 16h | 0% | 0% |
| 220 | 1.4.10 | **Proceso de Realmacenamiento en Unidades de Conservacion** |  | 22d | 2025-08-27 | 2025-09-25 | 213SS+2d | 51d |  |  | SKAPHE | 464h | 0% | 0% |
| 221 | 1.4.10.1 | Actividades de realmacenamiento |  | 20d | 2025-08-27 | 2025-09-23 | 207 | 51d | 0d | start no earlier than 2025-05-21 | SKAPHE | 160h | 0% | 0% |
| 222 | 1.4.10.2 | **Realizar entrega de libros** |  | 12d | 2025-09-09 | 2025-09-25 |  | 54d |  |  | SKAPHE | 128h | 0% | 0% |
| 223 | 1.4.10.2.1 | Entrega libros No 1 | milestone | 0d | 2025-09-09 | 2025-09-09 | 221SS+10d | 64d | 0d | start no earlier than 2025-06-25 | SKAPHE |  | 0% | 0% |
| 224 | 1.4.10.2.2 | Realizar aprobación entrega No 1 |  | 2d | 2025-09-10 | 2025-09-11 | 223 | 64d |  | finish no earlier than 2025-06-05 | SNR | 16h | 0% | 0% |
| 225 | 1.4.10.2.3 | Entrega libros No 2 | milestone | 0d | 2025-09-23 | 2025-09-23 | 221 | 51d | 0d | start no earlier than 2025-07-11 | SKAPHE |  | 0% | 0% |
| 226 | 1.4.10.2.4 | Realizar aprobación entrega No 2 |  | 2d | 2025-09-24 | 2025-09-25 | 225 | 51d | 0d | finish no earlier than 2025-07-02 | SNR | 16h | 0% | 0% |
| 227 | 1.4.11 | **Proceso de discos Duros** |  | 21d | 2025-09-02 | 2025-09-30 |  | 51d |  |  | SKAPHE | 440h | 0% | 0% |
| 228 | 1.4.11.1 | Copiado de discos duros |  | 19d | 2025-09-02 | 2025-09-26 | 214 | 51d | 0d | start no earlier than 2025-06-17 | SKAPHE | 152h | 0% | 0% |
| 229 | 1.4.11.2 | **Entrega de discos duros** |  | 11d | 2025-09-15 | 2025-09-30 | 213SS+3d | 51d |  |  | SKAPHE | 120h | 0% | 0% |
| 230 | 1.4.11.2.1 | Entrega libros No 1 | milestone | 0d | 2025-09-15 | 2025-09-15 | 228SS+10d | 60d | 0d | start no earlier than 2025-06-27 | SKAPHE |  | 0% | 0% |
| 231 | 1.4.11.2.2 | Realizar aprobación entrega No 1 |  | 2d | 2025-09-16 | 2025-09-17 | 230 | 60d |  | start no earlier than 2025-06-27 | SNR | 16h | 0% | 0% |
| 232 | 1.4.11.2.3 | Entrega libros No 2 | milestone | 0d | 2025-09-26 | 2025-09-26 | 228 | 51d | 0d | start no earlier than 2025-07-16 | SKAPHE |  | 0% | 0% |
| 233 | 1.4.11.2.4 | Realizar aprobación entrega No 2 |  | 2d | 2025-09-29 | 2025-09-30 | 232 | 51d |  |  | SNR | 16h | 0% | 0% |
| 234 | 1.4.12 | Traslado de Libros del Antiguo Sistema Registral al Archivo Central |  | 1d | 2025-09-30 | 2025-09-30 | 226FS+2d | 51d |  | start no earlier than 2025-07-18 | SKAPHE | 8h | 0% | 0% |
| 235 | 1.4.13 | Intervencion tecnica por Demanda /Prestamo de Unidades documentales en porceos de Digitalizacion |  | 100d | 2025-05-12 | 2025-10-01 |  | 50d | 0d | start no earlier than 2025-05-12 | SKAPHE | 800h | 0% | 0% |
| 236 | 1.4.14 | Control Calidad Tranversal procesos |  | 100d | 2025-05-12 | 2025-10-01 | 235FF | 50d |  | start no earlier than 2025-05-12 | SKAPHE | 800h | 0% | 0% |

Notes:
- 209: 170 libros
- 211: 178 libros
- 216: 170 libros
- 218: 178 libros
- 223: 170 libros
- 225: 178 libros
- 230: 170 libros
- 232: 178 libros

| ID | WBS | Task | Type | Duration | Start | Finish | Predecessors | Complete | Remaining | Total slack | Free slack | Constraint | Resources | Work | Actual work | %Planeado | %Retraso | Text30 |
| --- | --- | --- | --- | --- | --- | --- | --- | --- | --- | --- | --- | --- | --- | --- | --- | --- | --- | --- |
| 237 | 1.5 | **Carmen de Bolivar** |  | 130d | 2025-03-20 A | 2025-09-25 |  |  | 129.48d | 54d |  |  | SKAPHE | 4400h | 12.19h | 16% | 16% | G2 |
| 238 | 1.5.1 | Visita tecnica de reconocimieto |  | 1d | 2025-03-20 A | 2025-03-20 A |  | 100% |  |  |  | start no earlier than 2025-03-20 | SKAPHE | 8h | 8h | 100% | 0% |  |
| 239 | 1.5.2 | Entrega informe Visita Tecnica | milestone | 0d | 2025-04-02 A | 2025-04-02 A |  | 100% |  |  |  | start no earlier than 2025-03-31 | SKAPHE |  |  | 100% | 0% |  |
| 240 | 1.5.3 | **Saneamiento Ambiental Preventivo** |  | 21d | 2025-05-23 | 2025-06-24 |  |  |  | 30d |  |  | SKAPHE | 136h |  | 0% | 0% |  |
| 241 | 1.5.3.1 | Realizar actividades de saneamiento ambiental |  | 1d | 2025-05-23 | 2025-05-23 | 196FS-1d |  |  | 30d | 0d | start no earlier than 2025-05-08 | SKAPHE | 8h |  | 0% | 0% |  |
| 242 | 1.5.3.2 | Entrega de Informe Saneamiento Ambiental Preventivo | milestone | 0d | 2025-06-24 | 2025-06-24 |  |  |  | 120d |  | start no earlier than 2025-06-24 | SKAPHE |  |  | 0% | 0% |  |
| 243 | 1.5.4 | Alistamiento, Entrega y Embalaje |  | 9d | 2025-05-26 | 2025-06-06 | 196, 241 |  |  | 30d | 0d | start no earlier than 2025-05-20 | SKAPHE | 72h |  | 0% | 0% |  |
| 244 | 1.5.5 | Cargue, Traslado y descargue |  | 1d | 2025-06-09 | 2025-06-09 | 243 |  |  | 30d | 0d | start no earlier than 2025-05-30 | SKAPHE | 8h |  | 0% | 0% |  |
| 245 | 1.5.6 | Entrega de informe | milestone | 0d | 2025-06-24 | 2025-06-24 | 244 |  |  | 120d |  | start no earlier than 2025-06-24 | SKAPHE |  |  | 0% | 0% |  |
| 246 | 1.5.7 | **Proceso de Intervención en Conservación Documental-Primeros Auxilios** |  | 28d | 2025-06-12 | 2025-07-21 |  |  |  | 60d |  |  | SKAPHE | 536h |  | 0% | 0% |  |
| 247 | 1.5.7.1 | Actividades de conservación primeros auxilios |  | 20d | 2025-06-12 | 2025-07-09 | 244FS+2d |  |  | 60d | 3d | start no earlier than 2025-06-03 | SKAPHE | 160h |  | 0% | 0% |  |
| 248 | 1.5.7.2 | **Realizar entrega de libros** |  | 15d | 2025-07-01 | 2025-07-21 |  |  |  | 67d |  |  | SKAPHE | 152h |  | 0% | 0% |  |
| 249 | 1.5.7.2.1 | Entrega libros No 1 | milestone | 0d | 2025-07-01 | 2025-07-01 | 247SS+10d |  |  | 113d | 0d | start no earlier than 2025-07-01 | SKAPHE |  |  | 0% | 0% |  |
| 250 | 1.5.7.2.2 | Realizar aprobación entrega No 1 |  | 2d | 2025-07-01 | 2025-07-02 | 249 |  |  | 113d |  |  | SNR | 16h |  | 0% | 0% |  |
| 251 | 1.5.7.2.3 | Entrega libros No 2 | milestone | 0d | 2025-07-18 | 2025-07-18 | 247 |  |  | 54d | 0d | start no earlier than 2025-07-18 | SKAPHE |  |  | 0% | 0% |  |
| 252 | 1.5.7.2.4 | Realizar aprobación entrega No 2 |  | 2d | 2025-07-18 | 2025-07-21 | 251 |  |  | 54d | 0d |  | SNR | 16h |  | 0% | 0% |  |
| 253 | 1.5.8 | **Proceso de Digitalizacion** |  | 22d | 2025-07-22 | 2025-08-22 |  |  |  | 54d |  |  | SKAPHE | 464h |  | 0% | 0% |  |
| 254 | 1.5.8.1 | Actividades de digitalización |  | 20d | 2025-07-22 | 2025-08-20 | 252 |  |  | 54d | 0d |  | SKAPHE | 160h |  | 0% | 0% |  |
| 255 | 1.5.8.2 | **Realizar entrega de libros** |  | 12d | 2025-08-04 | 2025-08-22 |  |  |  | 54d |  |  | SKAPHE | 128h |  | 0% | 0% |  |
| 256 | 1.5.8.2.1 | Entrega libros No 1 | milestone | 0d | 2025-08-04 | 2025-08-04 | 254SS+10d |  |  | 54d | 0d | start no earlier than 2025-07-03 | SKAPHE |  |  | 0% | 0% |  |
| 257 | 1.5.8.2.2 | Realizar aprobación entrega No 1 |  | 2d | 2025-08-05 | 2025-08-06 | 256 |  |  | 54d | 0d |  | SNR | 16h |  | 0% | 0% |  |
| 258 | 1.5.8.2.3 | Entrega libros No 2 | milestone | 0d | 2025-08-20 | 2025-08-20 | 254 |  |  | 78d | 0d | start no earlier than 2025-08-05 | SKAPHE |  |  | 0% | 0% |  |
| 259 | 1.5.8.2.4 | Realizar aprobación entrega No 2 |  | 2d | 2025-08-21 | 2025-08-22 | 258 |  |  | 78d |  |  | SNR | 16h |  | 0% | 0% |  |
| 260 | 1.5.9 | **Proceso de Descripcion e Indexacion** |  | 22d | 2025-08-08 | 2025-09-09 |  |  |  | 54d |  |  | SKAPHE | 464h |  | 0% | 0% |  |
| 261 | 1.5.9.1 | Actividades de descripción e indexación |  | 20d | 2025-08-08 | 2025-09-05 | 257 |  |  | 54d | 0d | start no earlier than 2025-07-14 | SKAPHE | 160h |  | 0% | 0% |  |

Notes:
- 239: Entrega Informe
- 242: Entrega Informe
- 244: 348 libros
- 245: Entrega Informe
- 249: 110 libros
- 251: 129 libros
- 256: 110 libros
- 258: 129 libros

| ID | WBS | Task | Type | Duration | Start | Finish | Predecessors | Complete | Remaining | Total slack | Free slack | Constraint | Resources | Work | Actual work | %Planeado | %Retraso | Text30 |
| --- | --- | --- | --- | --- | --- | --- | --- | --- | --- | --- | --- | --- | --- | --- | --- | --- | --- | --- |
| 262 | 1.5.9.2 | **Realizar entrega de libros** |  | 12d | 2025-08-22 | 2025-09-09 |  |  |  | 54d |  |  | SKAPHE | 128h |  | 0% | 0% |  |
| 263 | 1.5.9.2.1 | Entrega libros No 1 | milestone | 0d | 2025-08-22 | 2025-08-22 | 261SS+10d |  |  | 60d | 0d | start no earlier than 2025-07-24 | SKAPHE |  |  | 0% | 0% |  |
| 264 | 1.5.9.2.2 | Realizar aprobación entrega No 1 |  | 2d | 2025-08-25 | 2025-08-26 | 263 |  |  | 62d | 8d | finish no earlier than 2025-06-24 | SNR | 16h |  | 0% | 0% |  |
| 265 | 1.5.9.2.3 | Entrega libros No 2 | milestone | 0d | 2025-09-05 | 2025-09-05 | 264, 261 |  |  | 54d | 0d | start no earlier than 2025-08-12 | SKAPHE |  |  | 0% | 0% |  |
| 266 | 1.5.9.2.4 | Realizar aprobación entrega No 2 |  | 2d | 2025-09-08 | 2025-09-09 | 265 |  |  | 54d | 0d | start no earlier than 2025-07-11 | SNR | 16h |  | 0% | 0% |  |
| 267 | 1.5.10 | **Proceso de Realmacenamiento en Unidades de Conservacion** |  | 17d | 2025-08-25 | 2025-09-16 | 263 |  |  | 60d |  |  | SKAPHE | 360h |  | 0% | 0% |  |
| 268 | 1.5.10.1 | Actividades de realmacenamiento |  | 15d | 2025-08-25 | 2025-09-12 | 257, 254 |  |  | 60d | 0d | start no earlier than 2025-07-24 | SKAPHE | 120h |  | 0% | 0% |  |
| 269 | 1.5.10.2 | **Realizar entrega de libros** |  | 9d | 2025-09-03 | 2025-09-16 |  |  |  | 60d |  |  | SKAPHE | 104h |  | 0% | 0% |  |
| 270 | 1.5.10.2.1 | Entrega libros No 1 | milestone | 0d | 2025-09-03 | 2025-09-03 | 268SS+8d |  |  | 65d | 0d | start no earlier than 2025-07-29 | SKAPHE |  |  | 0% | 0% |  |
| 271 | 1.5.10.2.2 | Realizar aprobación entrega No 1 |  | 2d | 2025-09-04 | 2025-09-05 | 270 |  |  | 65d | 5d |  | SNR | 16h |  | 0% | 0% |  |
| 272 | 1.5.10.2.3 | Entrega libros No 2 | milestone | 0d | 2025-09-12 | 2025-09-12 | 271, 268 |  |  | 60d | 0d | start no earlier than 2025-08-14 | SKAPHE |  |  | 0% | 0% |  |
| 273 | 1.5.10.2.4 | Realizar aprobación entrega No 2 | milestone | 2d | 2025-09-15 | 2025-09-16 | 272 |  |  | 60d | 0d | finish no earlier than 2025-07-14 | SNR | 16h |  | 0% | 0% |  |
| 274 | 1.5.11 | **Proceso de discos Duros** |  | 12d | 2025-09-10 | 2025-09-25 |  |  |  | 54d |  |  | SKAPHE | 264h |  | 0% | 0% |  |
| 275 | 1.5.11.1 | Copiado de discos duros | milestone | 10d | 2025-09-10 | 2025-09-23 | 264, 266 |  |  | 54d | 0d | start no earlier than 2025-07-22 | SKAPHE | 80h |  | 0% | 0% |  |
| 276 | 1.5.11.2 | **Entrega de discos duros** |  | 7d | 2025-09-16 | 2025-09-25 |  |  |  | 54d |  |  | SKAPHE | 88h |  | 0% | 0% |  |
| 277 | 1.5.11.2.1 | Entrega libros No 1 | milestone | 0d | 2025-09-16 | 2025-09-16 | 275SS+5d |  |  | 59d | 0d | start no earlier than 2025-07-28 | SKAPHE |  |  | 0% | 0% |  |
| 278 | 1.5.11.2.2 | Realizar aprobación entrega No 1 | milestone | 2d | 2025-09-17 | 2025-09-18 | 277 |  |  | 59d |  | finish no earlier than 2025-06-30 | SNR | 16h |  | 0% | 0% |  |
| 279 | 1.5.11.2.3 | Entrega libros No 2 | milestone | 0d | 2025-09-23 | 2025-09-23 | 277, 275 |  |  | 54d | 0d | start no earlier than 2025-08-14 | SKAPHE |  |  | 0% | 0% |  |
| 280 | 1.5.11.2.4 | Realizar aprobación entrega No 2 |  | 2d | 2025-09-24 | 2025-09-25 | 279SS |  |  | 54d |  | finish no earlier than 2025-07-17 | SNR | 16h |  | 0% | 0% |  |
| 281 | 1.5.12 | Traslado de Libros del Antiguo Sistema Registral al Archivo Central | milestone | 1d | 2025-09-17 | 2025-09-17 | 273 |  |  | 60d |  | start no earlier than 2025-08-15 | SKAPHE | 8h |  | 0% | 0% |  |
| 282 | 1.5.13 | Intervencion tecnica por Demanda /Prestamo de Unidades documentales en porceos de Digitalizacion | milestone | 65d | 2025-06-09 | 2025-09-09 | 238SS, 244SS |  |  | 66d | 0d | start no earlier than 2025-03-20 | SKAPHE | 520h |  | 0% | 0% |  |
| 283 | 1.5.14 | Control Calidad Tranversal procesos |  | 65d | 2025-06-09 | 2025-09-09 | 282SS |  |  | 66d |  | start no earlier than 2025-03-20 | SKAPHE | 520h |  | 0% | 0% |  |
| 284 | 1.6 | **Cerete** |  | 172d | 2025-03-20 A | 2025-11-27 |  |  | 171.6d | 12d |  |  | SKAPHE | 7440h | 11.21h | 12% | 12% | G1 |
| 285 | 1.6.1 | Visita tecnica de reconocimieto |  | 1d | 2025-03-20 A | 2025-03-20 A |  | 100% |  |  |  | start no earlier than 2025-03-20 | SKAPHE | 8h | 8h | 100% | 0% |  |
| 286 | 1.6.2 | Entrega informe Visita Tecnica | milestone | 0d | 2025-04-02 A | 2025-04-02 A |  | 100% |  |  |  | start no earlier than 2025-03-31 | SKAPHE |  |  | 100% | 0% |  |

Notes:
- 263: 110 libros
- 265: 129 libros
- 270: 110 libros
- 272: 129 libros
- 277: 110 libros
- 279: 129 libros

| ID | WBS | Task | Type | Duration | Start | Finish | Predecessors | Total slack | Free slack | Constraint | Resources | Work | %Planeado | %Retraso |
| --- | --- | --- | --- | --- | --- | --- | --- | --- | --- | --- | --- | --- | --- | --- |
| 287 | 1.6.3 | **Saneamiento Ambiental Preventivo** |  | 25d | 2025-05-13 | 2025-06-18 |  | 19d |  |  | SKAPHE | 40h | 0% | 0% |
| 288 | 1.6.3.1 | Actividades de saneamiento |  | 1d | 2025-05-13 | 2025-05-13 | 53FS-2d | 19d | 0d | start no earlier than 2025-05-13 | SKAPHE | 8h | 0% | 0% |
| 289 | 1.6.3.2 | Entrega de Informe Saneamiento Ambiental Preventivo | milestone | 0d | 2025-06-18 | 2025-06-18 |  | 124d |  | start no earlier than 2025-06-18 | SKAPHE |  | 0% | 0% |
| 290 | 1.6.4 | Alistamiento, Entrega y Embalaje |  | 11d | 2025-05-14 | 2025-05-28 | 288 | 19d | 0d | start no earlier than 2025-05-12 | SKAPHE | 88h | 0% | 0% |
| 291 | 1.6.5 | Cargue, Traslado y descargue |  | 1d | 2025-05-29 | 2025-05-29 | 290 | 19d | 1d |  | SKAPHE | 8h | 0% | 0% |
| 292 | 1.6.6 | Realizar entrega de informe | milestone | 0d | 2025-06-18 | 2025-06-18 |  | 124d |  | start no earlier than 2025-06-18 | SKAPHE |  | 0% | 0% |
| 293 | 1.6.7 | **Proceso de Intervención en Conservación Documental-Primeros Auxilios** |  | 47d | 2025-06-09 | 2025-08-13 |  | 17d |  |  | SKAPHE | 984h | 0% | 0% |
| 294 | 1.6.7.1 | Actividades de primeros auxilios |  | 45d | 2025-06-09 | 2025-08-11 | 291FS+3d | 17d | 0d | start no earlier than 2025-06-09 | SKAPHE | 360h | 0% | 0% |
| 295 | 1.6.7.2 | **Realizar entregas de libros** |  | 27d | 2025-07-04 | 2025-08-13 |  | 17d |  |  | SKAPHE | 248h | 0% | 0% |
| 296 | 1.6.7.2.1 | Entrega libros No 1 | milestone | 0d | 2025-07-04 | 2025-07-04 | 294SS+20d | 17d | 0d | start no earlier than 2025-06-27 | SKAPHE |  | 0% | 0% |
| 297 | 1.6.7.2.2 | Aprobación entrega No 1 |  | 2d | 2025-07-07 | 2025-07-08 | 296 | 17d | 0d | finish no earlier than 2025-05-13 | SNR | 16h | 0% | 0% |
| 298 | 1.6.7.2.3 | Entrega de libros No 2 | milestone | 0d | 2025-08-11 | 2025-08-11 | 294 | 84d | 0d | start no earlier than 2025-08-11 | SKAPHE |  | 0% | 0% |
| 299 | 1.6.7.2.4 | Aprobación entrega No 2 |  | 2d | 2025-08-12 | 2025-08-13 | 298 | 84d |  | finish no earlier than 2025-05-30 | SNR | 16h | 0% | 0% |
| 300 | 1.6.8 | **Proceso de Digitalizacion** |  | 42d | 2025-07-09 | 2025-09-08 |  | 17d |  |  | SKAPHE | 864h | 0% | 0% |
| 301 | 1.6.8.1 | Realizar actividades de digitalización |  | 40d | 2025-07-09 | 2025-09-04 | 297 | 17d | 0d | start no earlier than 2025-07-07 | SKAPHE | 320h | 0% | 0% |
| 302 | 1.6.8.2 | **Realizar Entrega de libros** |  | 22d | 2025-08-05 | 2025-09-08 |  | 25d |  |  | SKAPHE | 208h | 0% | 0% |
| 303 | 1.6.8.2.1 | Entrega libros No 1 | milestone | 0d | 2025-08-05 | 2025-08-05 | 301SS+20d | 45d | 0d | start no earlier than 2025-07-04 | SKAPHE |  | 0% | 0% |
| 304 | 1.6.8.2.2 | Aprobación entrega No 1 |  | 2d | 2025-08-06 | 2025-08-08 | 303 | 45d | 0d | finish no earlier than 2025-05-15 | SNR | 16h | 0% | 0% |
| 305 | 1.6.8.2.3 | Entrega de libros No 2 | milestone | 0d | 2025-09-04 | 2025-09-04 | 301 | 17d | 0d | start no earlier than 2025-08-15 | SKAPHE |  | 0% | 0% |
| 306 | 1.6.8.2.4 | Aprobación entrega No 2 |  | 2d | 2025-09-05 | 2025-09-08 | 305 | 17d | 0d | finish no earlier than 2025-06-04 | SNR | 16h | 0% | 0% |
| 307 | 1.6.9 | **Proceso de Descripcion e Indexacion** |  | 42d | 2025-08-11 | 2025-10-08 |  | 45d |  |  | SKAPHE | 864h | 0% | 0% |
| 308 | 1.6.9.1 | Realizar actividades de descripción e indexación |  | 40d | 2025-08-11 | 2025-10-06 | 304 | 45d | 0d | start no earlier than 2025-07-24 | SKAPHE | 320h | 0% | 0% |
| 309 | 1.6.9.2 | **Realizar entrega de libros** |  | 22d | 2025-09-08 | 2025-10-08 |  | 45d |  |  | SKAPHE | 208h | 0% | 0% |
| 310 | 1.6.9.2.1 | Entrega de libros No 1 | milestone | 0d | 2025-09-08 | 2025-09-08 | 308SS+20d | 65d | 0d | start no earlier than 2025-07-14 | SKAPHE |  | 0% | 0% |
| 311 | 1.6.9.2.2 | Aprobación entrega No 1 |  | 2d | 2025-09-09 | 2025-09-10 | 310 | 65d | 0d | finish no earlier than 2025-05-21 | SNR | 16h | 0% | 0% |
| 312 | 1.6.9.2.3 | Entrega de libros No 2 | milestone | 0d | 2025-10-06 | 2025-10-06 | 308 | 45d | 0d | start no earlier than 2025-08-28 | SKAPHE |  | 0% | 0% |
| 313 | 1.6.9.2.4 | Aprobación entrega No 2 |  | 2d | 2025-10-07 | 2025-10-08 | 312 | 45d |  | start no earlier than 2025-06-11 | SNR | 16h | 0% | 0% |

Notes:
- 296: 100 libros
- 298: 226 libros
- 303: 100 libros
- 305: 226 libros
- 310: 100 libros
- 312: 226 libros

| ID | WBS | Task | Type | Duration | Start | Finish | Predecessors | Complete | Remaining | Total slack | Free slack | Constraint | Resources | Work | Actual work | %Planeado | %Retraso | Text30 |
| --- | --- | --- | --- | --- | --- | --- | --- | --- | --- | --- | --- | --- | --- | --- | --- | --- | --- | --- |
| 314 | 1.6.10 | **Proceso de Realmacenamiento en Unidades de Conservacion** |  | 50d | 2025-09-09 | 2025-11-20 |  |  |  | 17d |  |  | SKAPHE | 872h |  | 0% | 0% |  |
| 315 | 1.6.10.1 | Realizar actividades de realmacenamiento |  | 10d | 2025-09-09 | 2025-09-22 | 306 |  |  | 17d | 0d | start no earlier than 2025-08-11 | SKAPHE | 80h |  | 0% | 0% |  |
| 316 | 1.6.10.2 | **Realizar entrega de libros** |  | 45d | 2025-09-15 | 2025-11-20 |  |  |  | 17d |  |  | SKAPHE | 392h |  | 0% | 0% |  |
| 317 | 1.6.10.2.1 | Entrega libros No 1 | milestone | 0d | 2025-09-15 | 2025-09-15 | 315SS+5d |  |  | 17d | 0d | start no earlier than 2025-08-15 | SKAPHE |  |  | 0% | 0% |  |
| 318 | 1.6.10.2.2 | Aprobación entrega No 1 |  | 45d | 2025-09-16 | 2025-11-20 | 317 |  |  | 17d |  |  | SNR | 16h |  | 0% | 0% |  |
| 319 | 1.6.10.2.3 | Entrega de libros No 2 | milestone | 0d | 2025-09-22 | 2025-09-22 | 315 |  |  | 55d | 0d | start no earlier than 2025-09-05 | SKAPHE |  |  | 0% | 0% |  |
| 320 | 1.6.10.2.4 | Aprobación entrega No 2 | milestone | 2d | 2025-09-23 | 2025-09-24 | 319 |  |  | 55d |  | finish no earlier than 2025-06-16 | SNR | 16h |  | 0% | 0% |  |
| 321 | 1.6.11 | **Proceso Discos Duros** |  | 38d | 2025-10-01 | 2025-11-26 |  |  |  | 12d |  |  | SKAPHE | 888h |  | 0% | 0% |  |
| 322 | 1.6.11.1 | Realizar copiado de DD | milestone | 36d | 2025-10-01 | 2025-11-24 | 311SS+16d |  |  | 12d | 0d | start no earlier than 2025-08-11 | SKAPHE | 288h |  | 0% | 0% |  |
| 323 | 1.6.11.2 | **Realizar entrega de DD** |  | 33d | 2025-10-07 | 2025-11-26 |  |  |  | 13d |  |  | SKAPHE | 296h |  | 0% | 0% |  |
| 324 | 1.6.11.2.1 | Entrega libros No 1 | milestone | 0d | 2025-10-07 | 2025-10-07 | 322SS+5d |  |  | 44d | 0d | start no earlier than 2025-08-18 | SKAPHE |  |  | 0% | 0% |  |
| 325 | 1.6.11.2.2 | Aprobación entrega No 1 | milestone | 2d | 2025-10-08 | 2025-10-09 | 324 |  |  | 44d |  | finish no earlier than 2025-05-28 | SNR | 16h |  | 0% | 0% |  |
| 326 | 1.6.11.2.3 | Entrega de libros No 2 | milestone | 0d | 2025-11-24 | 2025-11-24 | 322 |  |  | 12d | 0d | start no earlier than 2025-09-08 | SKAPHE |  |  | 0% | 0% |  |
| 327 | 1.6.11.2.4 | Aprobación entrega No 2 |  | 2d | 2025-11-25 | 2025-11-26 | 326SS |  |  | 12d | 0d | finish no earlier than 2025-06-16 | SNR | 16h |  | 0% | 0% |  |
| 328 | 1.6.12 | Traslado de Libros del Antiguo Sistema Registral al Archivo Central | milestone | 1d | 2025-11-27 | 2025-11-27 | 327 |  |  | 12d |  | start no earlier than 2025-10-01 | SKAPHE | 8h |  | 0% | 0% |  |
| 329 | 1.6.13 | Intervencion tecnica por Demanda /Prestamo de Unidades documentales en porceos de Digitalizacion | milestone | 90d | 2025-06-04 | 2025-10-09 | 290FS+1d |  |  | 44d | 0d | start no earlier than 2025-06-04 | SKAPHE | 720h |  | 0% | 0% |  |
| 330 | 1.6.14 | Control Calidad Tranversal procesos |  | 90d | 2025-06-04 | 2025-10-09 | 291SS, 329SS |  |  | 44d |  | start no earlier than 2025-03-18 | SKAPHE | 720h |  | 0% | 0% |  |
| 331 | 1.7 | **Sahagun** |  | 151d | 2025-03-20 A | 2025-10-27 |  |  | 150.59d | 33d |  |  | SKAPHE | 6144h | 11.29h | 14% | 14% | G1 |
| 332 | 1.7.1 | Visita tecnica de reconocimieto |  | 1d | 2025-03-20 A | 2025-03-20 A |  | 100% |  |  |  | start no earlier than 2025-03-20 | SKAPHE | 8h | 8h | 100% | 0% |  |
| 333 | 1.7.2 | Entrega informe Visita Tecnica | milestone | 0d | 2025-04-02 A | 2025-04-02 A |  | 100% |  |  |  | start no earlier than 2025-03-31 | SKAPHE |  |  | 100% | 0% |  |
| 334 | 1.7.3 | **Saneamiento Ambiental Preventivo** |  | 25d | 2025-05-29 | 2025-07-04 |  |  |  | 41d |  |  | SKAPHE | 120h |  | 0% | 0% |  |
| 335 | 1.7.3.1 | Actividades de saneamiento |  | 1d | 2025-05-29 | 2025-05-29 | 291FS-2d |  |  | 41d | 0d | start no earlier than 2025-05-29 | SKAPHE | 8h |  | 0% | 0% |  |
| 336 | 1.7.3.2 | Entrega de Informe Saneamiento Ambiental Preventivo | milestone | 0d | 2025-07-04 | 2025-07-04 |  |  |  | 112d |  | start no earlier than 2025-07-04 | SKAPHE |  |  | 0% | 0% |  |
| 337 | 1.7.4 | Alistamiento, Entrega y Embalaje |  | 12d | 2025-05-30 | 2025-06-17 | 335 |  |  | 41d | 0d | start no earlier than 2025-05-28 | SKAPHE | 96h |  | 0% | 0% |  |
| 338 | 1.7.5 | Cargue, Traslado y descargue |  | 1d | 2025-06-18 | 2025-06-18 | 337 |  |  | 41d | 2d | start no earlier than 2025-06-13 | SKAPHE | 8h |  | 0% | 0% |  |
| 339 | 1.7.6 | Realizar entrega de informe | milestone | 0d | 2025-07-04 | 2025-07-04 |  |  |  | 112d |  | start no earlier than 2025-07-04 | SKAPHE |  |  | 0% | 0% |  |

Notes:
- 317: 100 libros
- 319: 226 libros
- 324: 100 libros
- 326: 226 libros

| ID | WBS | Task | Type | Duration | Start | Finish | Predecessors | Total slack | Free slack | Constraint | Resources | Work | %Planeado | %Retraso |
| --- | --- | --- | --- | --- | --- | --- | --- | --- | --- | --- | --- | --- | --- | --- |
| 340 | 1.7.7 | **Proceso de Intervención en Conservación Documental-Primeros Auxilios** |  | 38d | 2025-06-26 | 2025-08-20 |  | 39d |  |  | SKAPHE | 1040h | 0% | 0% |
| 341 | 1.7.7.1 | Conservación |  | 35d | 2025-06-26 | 2025-08-14 | 338FS+3d | 39d | 0d | start no earlier than 2025-06-26 | SKAPHE | 280h | 0% | 0% |
| 342 | 1.7.7.2 | Desencuadernación e historia clinica |  | 35d | 2025-06-26 | 2025-08-14 | 338FS+3d | 83d |  | start no earlier than 2025-06-26 | SKAPHE | 280h | 0% | 0% |
| 343 | 1.7.7.3 | **Realizar entregas de libros** |  | 18d | 2025-07-23 | 2025-08-20 |  | 39d |  |  | SKAPHE | 176h | 0% | 0% |
| 344 | 1.7.7.3.1 | Entrega libros No 1 | milestone | 0d | 2025-07-23 | 2025-07-23 | 341SS+20d | 39d | 0d | start no earlier than 2025-07-17 | SKAPHE |  | 0% | 0% |
| 345 | 1.7.7.3.2 | Aprobación entrega No 1 |  | 2d | 2025-07-24 | 2025-07-25 | 344 | 39d | 6d |  | SNR | 16h | 0% | 0% |
| 346 | 1.7.7.3.3 | Entrega de libros No 2 | milestone | 0d | 2025-08-15 | 2025-08-15 | 341FS+1d | 80d | 0d | start no earlier than 2025-08-15 | SKAPHE |  | 0% | 0% |
| 347 | 1.7.7.3.4 | Aprobación entrega No 2 |  | 2d | 2025-08-19 | 2025-08-20 | 346 | 80d |  |  | SNR | 16h | 0% | 0% |
| 348 | 1.7.8 | **Proceso de Digitalizacion** |  | 34d | 2025-08-05 | 2025-09-23 |  | 33d |  |  | SKAPHE | 696h | 0% | 0% |
| 349 | 1.7.8.1 | Realizar actividades de digitalización |  | 30d | 2025-08-05 | 2025-09-17 | 345 | 33d | 0d | start no earlier than 2025-08-05 | SKAPHE | 240h | 0% | 0% |
| 350 | 1.7.8.2 | **Realizar Entrega de libros** |  | 19d | 2025-08-27 | 2025-09-23 |  | 33d |  |  | SKAPHE | 184h | 0% | 0% |
| 351 | 1.7.8.2.1 | Entrega libros No 1 | milestone | 0d | 2025-08-27 | 2025-08-27 | 345SF, 349SS+15d | 33d | 0d | start no earlier than 2025-08-15 | SKAPHE |  | 0% | 0% |
| 352 | 1.7.8.2.2 | Aprobación entrega No 1 |  | 2d | 2025-08-28 | 2025-08-29 | 351 | 33d | 0d |  | SNR | 16h | 0% | 0% |
| 353 | 1.7.8.2.3 | Entrega de libros No 2 | milestone | 0d | 2025-09-22 | 2025-09-22 | 349 | 56d | 0d | start no earlier than 2025-09-22 | SKAPHE |  | 0% | 0% |
| 354 | 1.7.8.2.4 | Aprobación entrega No 2 |  | 2d | 2025-09-22 | 2025-09-23 | 353 | 56d |  |  | SNR | 16h | 0% | 0% |
| 355 | 1.7.9 | **Proceso de Descripcion e Indexacion** |  | 32d | 2025-09-01 | 2025-10-15 |  | 33d |  |  | SKAPHE | 664h | 0% | 0% |
| 356 | 1.7.9.1 | Realizar actividades de descripción e indexación |  | 30d | 2025-09-01 | 2025-10-10 | 352 | 33d | 0d | start no earlier than 2025-08-13 | SKAPHE | 240h | 0% | 0% |
| 357 | 1.7.9.2 | **Realizar entrega de libros** |  | 17d | 2025-09-19 | 2025-10-15 |  | 33d |  |  | SKAPHE | 168h | 0% | 0% |
| 358 | 1.7.9.2.1 | Entrega de libros No 1 | milestone | 0d | 2025-09-19 | 2025-09-19 | 356SS+15d | 33d | 0d | start no earlier than 2025-08-19 | SKAPHE |  | 0% | 0% |
| 359 | 1.7.9.2.2 | Aprobación entrega No 1 |  | 2d | 2025-09-22 | 2025-09-23 | 358 | 33d | 0d |  | SNR | 16h | 0% | 0% |
| 360 | 1.7.9.2.3 | Entrega de libros No 2 | milestone | 0d | 2025-10-10 | 2025-10-10 | 356 | 41d | 0d | start no earlier than 2025-09-25 | SKAPHE |  | 0% | 0% |
| 361 | 1.7.9.2.4 | Aprobación entrega No 2 |  | 2d | 2025-10-14 | 2025-10-15 | 360 | 41d |  |  | SNR | 16h | 0% | 0% |
| 362 | 1.7.10 | **Proceso de Realmacenamiento en Unidades de Conservacion** |  | 26d | 2025-09-01 | 2025-10-06 |  | 47d |  |  | SKAPHE | 520h | 0% | 0% |
| 363 | 1.7.10.1 | Realizar actividades de realmacenamiento |  | 18d | 2025-09-01 | 2025-09-24 | 352 | 53d | 0d | start no earlier than 2025-08-26 | SKAPHE | 144h | 0% | 0% |

Notes:
- 344: 168 libros
- 346: 200 libros
- 351: 168 libros
- 353: 200 libros
- 358: 168 libros
- 360: 200 libros

| ID | WBS | Task | Type | Duration | Start | Finish | Predecessors | Complete | Remaining | Total slack | Free slack | Constraint | Resources | Work | Actual work | %Planeado | %Retraso | Text30 |
| --- | --- | --- | --- | --- | --- | --- | --- | --- | --- | --- | --- | --- | --- | --- | --- | --- | --- | --- |
| 364 | 1.7.10.2 | **Realizar entrega de libros** |  | 17d | 2025-09-11 | 2025-10-06 |  |  |  | 47d |  |  | SKAPHE | 168h |  | 0% | 0% |  |
| 365 | 1.7.10.2.1 | Entrega libros No 1 | milestone | 0d | 2025-09-11 | 2025-09-11 | 363SS+9d |  |  | 62d | 0d | start no earlier than 2025-08-26 | SKAPHE |  |  | 0% | 0% |  |
| 366 | 1.7.10.2.2 | Aprobación entrega No 1 |  | 2d | 2025-09-12 | 2025-09-15 | 365 |  |  | 62d |  |  | SNR | 16h |  | 0% | 0% |  |
| 367 | 1.7.10.2.3 | Entrega de libros No 2 | milestone | 0d | 2025-10-03 | 2025-10-03 | 363 |  |  | 47d | 0d | start no earlier than 2025-10-03 | SKAPHE |  |  | 0% | 0% |  |
| 368 | 1.7.10.2.4 | Aprobación entrega No 2 |  | 2d | 2025-10-03 | 2025-10-06 | 367 |  |  | 47d |  |  | SNR | 16h |  | 0% | 0% |  |
| 369 | 1.7.11 | **Proceso Discos Duros** |  | 23d | 2025-09-24 | 2025-10-27 |  |  |  | 33d |  |  | SKAPHE | 480h |  | 0% | 0% |  |
| 370 | 1.7.11.1 | Realizar copiado de DD |  | 21d | 2025-09-24 | 2025-10-23 | 359 |  |  | 33d | 0d | start no earlier than 2025-08-26 | SKAPHE | 168h |  | 0% | 0% |  |
| 371 | 1.7.11.2 | **Realizar entrega de DD** |  | 12d | 2025-10-08 | 2025-10-27 |  |  |  | 33d |  |  | SKAPHE | 128h |  | 0% | 0% |  |
| 372 | 1.7.11.2.1 | Entrega libros No 1 | milestone | 0d | 2025-10-08 | 2025-10-08 | 370SS+11d |  |  | 43d | 0d | start no earlier than 2025-08-29 | SKAPHE |  |  | 0% | 0% |  |
| 373 | 1.7.11.2.2 | Aprobación entrega No 1 |  | 2d | 2025-10-09 | 2025-10-10 | 372 |  |  | 43d |  |  | SNR | 16h |  | 0% | 0% |  |
| 374 | 1.7.11.2.3 | Entrega de libros No 2 | milestone | 0d | 2025-10-23 | 2025-10-23 | 370 |  |  | 33d | 0d | start no earlier than 2025-10-02 | SKAPHE |  |  | 0% | 0% |  |
| 375 | 1.7.11.2.4 | Aprobación entrega No 2 |  | 2d | 2025-10-24 | 2025-10-27 | 374 |  |  | 33d |  |  | SNR | 16h |  | 0% | 0% |  |
| 376 | 1.7.12 | Traslado de Libros del Antiguo Sistema Registral al Archivo Central |  | 1d | 2025-10-03 | 2025-10-03 | 363 |  |  | 48d |  | start no earlier than 2025-10-03 | SKAPHE | 8h |  | 0% | 0% |  |
| 377 | 1.7.13 | Intervencion tecnica por Demanda /Prestamo de Unidades documentales en porceos de Digitalizacion |  | 81d | 2025-06-11 | 2025-10-03 | 337SS |  |  | 48d | 0d | start no earlier than 2025-06-11 | SKAPHE | 648h |  | 0% | 0% |  |
| 378 | 1.7.14 | Control Calidad Tranversal procesos |  | 81d | 2025-06-11 | 2025-10-03 | 377SS |  |  | 48d |  | start no earlier than 2025-05-28 | SKAPHE | 648h |  | 0% | 0% |  |
| 379 | 1.8 | **Magangue** |  | 181d | 2025-03-21 A | 2025-12-12 |  |  | 180.45d | 2d |  |  | SKAPHE | 5648h | 12.38h | 11% | 11% | G2 |
| 380 | 1.8.1 | Visita tecnica de reconocimieto |  | 1d | 2025-03-21 A | 2025-03-21 A |  | 100% |  |  |  | start no earlier than 2025-03-21 | SKAPHE | 8h | 8h | 100% | 0% |  |
| 381 | 1.8.2 | Entrega informe Visita Tecnica | milestone | 0d | 2025-04-02 A | 2025-04-02 A |  | 100% |  |  |  | start no earlier than 2025-03-31 | SKAPHE |  |  | 100% | 0% |  |
| 382 | 1.8.3 | **Saneamiento Ambiental Preventivo** |  | 25d | 2025-06-10 | 2025-07-15 |  |  |  | 30d |  |  | SKAPHE | 144h |  | 0% | 0% |  |
| 383 | 1.8.3.1 | Realizar actividades de saneamiento ambiental |  | 1d | 2025-06-10 | 2025-06-10 | 244 |  |  | 30d | 0d | start no earlier than 2025-06-05 | SKAPHE | 8h |  | 0% | 0% |  |
| 384 | 1.8.3.2 | Entrega de Informe Saneamiento Ambiental Preventivo | milestone | 0d | 2025-07-15 | 2025-07-15 |  |  |  | 105d |  | start no earlier than 2025-07-15 | SKAPHE |  |  | 0% | 0% |  |
| 385 | 1.8.4 | Alistamiento, Entrega y Embalaje |  | 7d | 2025-06-11 | 2025-06-19 | 383 |  |  | 30d | 0d | start no earlier than 2025-06-04 | SKAPHE | 56h |  | 0% | 0% |  |
| 386 | 1.8.5 | Cargue, Traslado y descargue |  | 1d | 2025-06-20 | 2025-06-20 | 385 |  |  | 36d | 0d | start no earlier than 2025-06-16 | SKAPHE | 8h |  | 0% | 0% |  |
| 387 | 1.8.6 | Entrega de informe | milestone | 0d | 2025-07-15 | 2025-07-15 |  |  |  | 105d |  | start no earlier than 2025-07-15 | SKAPHE |  |  | 0% | 0% |  |

Notes:
- 365: 168 libros
- 367: 200 libros
- 372: 168 libros
- 374: 200 libros

| ID | WBS | Task | Type | Duration | Start | Finish | Predecessors | Total slack | Free slack | Constraint | Resources | Work | %Planeado | %Retraso |
| --- | --- | --- | --- | --- | --- | --- | --- | --- | --- | --- | --- | --- | --- | --- |
| 388 | 1.8.7 | **Proceso de Intervención en Conservación Documental-Primeros Auxilios** |  | 17d | 2025-09-15 | 2025-10-07 |  | 2d |  |  | SKAPHE | 360h | 0% | 0% |
| 389 | 1.8.7.1 | Actividades de conservación primeros auxilios |  | 15d | 2025-09-15 | 2025-10-03 | 386FS+3d | 2d | 0d | start no earlier than 2025-09-15 | SKAPHE | 120h | 0% | 0% |
| 390 | 1.8.7.2 | **Realizar entrega de libros** |  | 9d | 2025-09-24 | 2025-10-07 |  | 2d |  |  | SKAPHE | 104h | 0% | 0% |
| 391 | 1.8.7.2.1 | Entrega libros No 1 | milestone | 0d | 2025-09-24 | 2025-09-24 | 389SS+8d | 2d | 0d | start no earlier than 2025-09-22 | SKAPHE |  | 0% | 0% |
| 392 | 1.8.7.2.2 | Realizar aprobación entrega No 1 |  | 2d | 2025-09-25 | 2025-09-26 | 391 | 2d | 0d |  | SNR | 16h | 0% | 0% |
| 393 | 1.8.7.2.3 | Entrega libros No 2 | milestone | 0d | 2025-10-06 | 2025-10-06 | 389FS-4d | 46d | 0d | start no earlier than 2025-10-06 | SKAPHE |  | 0% | 0% |
| 394 | 1.8.7.2.4 | Realizar aprobación entrega No 2 |  | 2d | 2025-10-06 | 2025-10-07 | 393 | 46d |  |  | SNR | 16h | 0% | 0% |
| 395 | 1.8.8 | **Proceso de Digitalizacion** |  | 23d | 2025-09-29 | 2025-10-30 |  | 2d |  |  | SKAPHE | 496h | 0% | 0% |
| 396 | 1.8.8.1 | Actividades de digitalización |  | 21d | 2025-09-29 | 2025-10-28 | 392 | 2d | 0d | start no earlier than 2025-09-17 | SKAPHE | 168h | 0% | 0% |
| 397 | 1.8.8.2 | **Realizar entrega de libros** |  | 14d | 2025-10-09 | 2025-10-30 |  | 2d |  |  | SKAPHE | 144h | 0% | 0% |
| 398 | 1.8.8.2.1 | Entrega libros No 1 | milestone | 0d | 2025-10-09 | 2025-10-09 | 396SS+9d | 2d | 0d | start no earlier than 2025-09-29 | SKAPHE |  | 0% | 0% |
| 399 | 1.8.8.2.2 | Realizar aprobación entrega No 1 |  | 2d | 2025-10-10 | 2025-10-14 | 398 | 2d | 0d |  | SNR | 16h | 0% | 0% |
| 400 | 1.8.8.2.3 | Entrega libros No 2 | milestone | 0d | 2025-10-28 | 2025-10-28 | 396 | 30d | 0d | start no earlier than 2025-10-20 | SKAPHE |  | 0% | 0% |
| 401 | 1.8.8.2.4 | Realizar aprobación entrega No 2 |  | 2d | 2025-10-29 | 2025-10-30 | 400 | 30d |  |  | SNR | 16h | 0% | 0% |
| 402 | 1.8.9 | **Proceso de Descripcion e Indexacion** |  | 22d | 2025-10-15 | 2025-11-14 |  | 2d |  |  | SKAPHE | 456h | 0% | 0% |
| 403 | 1.8.9.1 | Actividades de descripción e indexación |  | 20d | 2025-10-15 | 2025-11-12 | 399 | 2d | 0d | start no earlier than 2025-09-29 | SKAPHE | 160h | 0% | 0% |
| 404 | 1.8.9.2 | **Realizar entrega de libros** |  | 11d | 2025-10-29 | 2025-11-14 |  | 2d |  |  | SKAPHE | 120h | 0% | 0% |
| 405 | 1.8.9.2.1 | Entrega libros No 1 | milestone | 0d | 2025-10-29 | 2025-10-29 | 403SS+11d | 2d | 0d | start no earlier than 2025-09-29 | SKAPHE |  | 0% | 0% |
| 406 | 1.8.9.2.2 | Realizar aprobación entrega No 1 |  | 2d | 2025-10-30 | 2025-10-31 | 405 | 2d | 0d |  | SNR | 16h | 0% | 0% |
| 407 | 1.8.9.2.3 | Entrega libros No 2 | milestone | 0d | 2025-11-12 | 2025-11-12 | 403 | 20d | 0d | start no earlier than 2025-10-27 | SKAPHE |  | 0% | 0% |
| 408 | 1.8.9.2.4 | Realizar aprobación entrega No 2 |  | 2d | 2025-11-13 | 2025-11-14 | 407 | 20d |  |  | SNR | 16h | 0% | 0% |
| 409 | 1.8.10 | **Proceso de Realmacenamiento en Unidades de Conservacion** |  | 23d | 2025-10-15 | 2025-11-18 |  | 19d |  |  | SKAPHE | 512h | 0% | 0% |
| 410 | 1.8.10.1 | Actividades de realmacenamiento |  | 21d | 2025-10-15 | 2025-11-13 | 399 | 19d | 0d | start no earlier than 2025-10-06 | SKAPHE | 168h | 0% | 0% |
| 411 | 1.8.10.2 | **Realizar entrega de libros** |  | 16d | 2025-10-23 | 2025-11-18 |  | 19d |  |  | SKAPHE | 160h | 0% | 0% |
| 412 | 1.8.10.2.1 | Entrega libros No 1 | milestone | 0d | 2025-10-23 | 2025-10-23 | 410SS+7d | 33d | 0d | start no earlier than 2025-10-06 | SKAPHE |  | 0% | 0% |
| 413 | 1.8.10.2.2 | Realizar aprobación entrega No 1 |  | 2d | 2025-10-24 | 2025-10-27 | 412 | 33d |  |  | SNR | 16h | 0% | 0% |
| 414 | 1.8.10.2.3 | Entrega libros No 2 | milestone | 0d | 2025-11-13 | 2025-11-13 | 410 | 19d | 0d | start no earlier than 2025-11-07 | SKAPHE |  | 0% | 0% |
| 415 | 1.8.10.2.4 | Realizar aprobación entrega No 2 |  | 2d | 2025-11-14 | 2025-11-18 | 414 | 19d |  |  | SNR | 16h | 0% | 0% |

Notes:
- 391: 82 libros
- 393: 82 libros
- 398: 82 libros
- 400: 82 libros
- 405: 82 libros
- 407: 82 libros
- 412: 82 libros
- 414: 82 libros

| ID | WBS | Task | Type | Duration | Start | Finish | Predecessors | Complete | Remaining | Total slack | Free slack | Constraint | Resources | Work | Actual work | %Planeado | %Retraso | Text30 |
| --- | --- | --- | --- | --- | --- | --- | --- | --- | --- | --- | --- | --- | --- | --- | --- | --- | --- | --- |
| 416 | 1.8.11 | **Proceso de discos Duros** |  | 27d | 2025-11-04 | 2025-12-12 |  |  |  | 2d |  |  | SKAPHE | 568h |  | 0% | 0% |  |
| 417 | 1.8.11.1 | Copiado de discos duros |  | 25d | 2025-11-04 | 2025-12-10 | 406 |  |  | 2d | 0d | start no earlier than 2025-10-31 | SKAPHE | 200h |  | 0% | 0% |  |
| 418 | 1.8.11.2 | **Entrega de discos duros** |  | 15d | 2025-11-20 | 2025-12-12 |  |  |  | 2d |  |  | SKAPHE | 152h |  | 0% | 0% |  |
| 419 | 1.8.11.2.1 | Entrega libros No 1 | milestone | 0d | 2025-11-20 | 2025-11-20 | 417SS+12d |  |  | 15d | 0d | start no earlier than 2025-10-06 | SKAPHE |  |  | 0% | 0% |  |
| 420 | 1.8.11.2.2 | Realizar aprobación entrega No 1 |  | 2d | 2025-11-21 | 2025-11-24 | 419 |  |  | 15d |  |  | SNR | 16h |  | 0% | 0% |  |
| 421 | 1.8.11.2.3 | Entrega libros No 2 | milestone | 0d | 2025-12-10 | 2025-12-10 | 417 |  |  | 2d | 0d | start no earlier than 2025-11-12 | SKAPHE |  |  | 0% | 0% |  |
| 422 | 1.8.11.2.4 | Realizar aprobación entrega No 2 |  | 2d | 2025-12-11 | 2025-12-12 | 421 |  |  | 2d |  |  | SNR | 16h |  | 0% | 0% |  |
| 423 | 1.8.12 | Traslado de Libros del Antiguo Sistema Registral al Archivo Central |  | 1d | 2025-11-14 | 2025-11-14 | 410 |  |  | 20d |  | start no earlier than 2025-11-14 | SKAPHE | 8h |  | 0% | 0% |  |
| 424 | 1.8.13 | Intervencion tecnica por Demanda /Prestamo de Unidades documentales en porceos de Digitalizacion |  | 99d | 2025-06-18 | 2025-11-07 | 385SS |  |  | 25d | 0d | start no earlier than 2025-06-18 | SKAPHE | 792h |  | 0% | 0% |  |
| 425 | 1.8.14 | Control Calidad Tranversal procesos |  | 99d | 2025-06-18 | 2025-11-07 | 424SS |  |  | 25d |  | start no earlier than 2025-03-21 | SKAPHE | 792h |  | 0% | 0% |  |
| 426 | 1.9 | **Monpox** |  | 164d | 2025-03-21 A | 2025-11-18 |  |  | 163.48d | 19d |  |  | SKAPHE | 5288h | 12.15h | 12% | 12% | G2 |
| 427 | 1.9.1 | Visita tecnica de reconocimieto |  | 1d | 2025-03-21 A | 2025-03-21 A |  | 100% |  |  |  | start no earlier than 2025-03-21 | SKAPHE | 8h | 8h | 100% | 0% |  |
| 428 | 1.9.2 | Entrega informe Visita Tecnica | milestone | 0d | 2025-04-02 A | 2025-04-02 A |  | 100% |  |  |  | start no earlier than 2025-03-31 | SKAPHE |  |  | 100% | 0% |  |
| 429 | 1.9.3 | **Saneamiento Ambiental Preventivo** |  | 30d | 2025-06-20 | 2025-08-04 |  |  |  | 36d |  |  | SKAPHE | 88h |  | 0% | 0% |  |
| 430 | 1.9.3.1 | Realizar actividades de saneamiento ambiental | milestone | 0d | 2025-06-20 | 2025-06-20 | 386 |  |  | 36d | 1d | start no earlier than 2025-06-20 | SKAPHE |  |  | 0% | 0% |  |
| 431 | 1.9.3.2 | Entrega de Informe Saneamiento Ambiental Preventivo | milestone | 0d | 2025-08-04 | 2025-08-04 |  |  |  | 91d |  | start no earlier than 2025-08-04 | SKAPHE |  |  | 0% | 0% |  |
| 432 | 1.9.4 | Alistamiento, Entrega y Embalaje |  | 12d | 2025-06-24 | 2025-07-09 | 430 |  |  | 35d | 0d | start no earlier than 2025-06-24 | SKAPHE | 96h |  | 0% | 0% |  |
| 433 | 1.9.5 | Cargue, Traslado y descargue |  | 1d | 2025-07-10 | 2025-07-10 | 432 |  |  | 35d | 11d | start no earlier than 2025-07-01 | SKAPHE | 8h |  | 0% | 0% |  |
| 434 | 1.9.6 | **Proceso de Intervención en Conservación Documental-Primeros Auxilios** |  | 32d | 2025-07-31 | 2025-09-16 |  |  |  | 24d |  |  | SKAPHE | 744h |  | 0% | 0% |  |
| 435 | 1.9.6.1 | Conservación |  | 26d | 2025-07-31 | 2025-09-08 | 433FS+3d |  |  | 24d | 0d | start no earlier than 2025-07-31 | SKAPHE | 208h |  | 0% | 0% |  |
| 436 | 1.9.6.2 | Desencuadernación e historia clinica |  | 26d | 2025-08-01 | 2025-09-09 | 433FS+3d |  |  | 66d |  | start no earlier than 2025-08-01 | SKAPHE | 208h |  | 0% | 0% |  |
| 437 | 1.9.6.3 | **Realizar entrega de libros** |  | 5d | 2025-09-10 | 2025-09-16 |  |  |  | 24d |  |  | SKAPHE | 72h |  | 0% | 0% |  |
| 438 | 1.9.6.3.1 | Entrega libros No 1 | milestone | 0d | 2025-09-10 | 2025-09-10 | 435FS+1d |  |  | 24d | 0d | start no earlier than 2025-09-10 | SKAPHE |  |  | 0% | 0% |  |
| 439 | 1.9.6.3.2 | Realizar aprobación entrega No 1 |  | 2d | 2025-09-10 | 2025-09-11 | 438 |  |  | 24d | 1d |  | SNR | 16h |  | 0% | 0% |  |
| 440 | 1.9.6.3.3 | Entrega libros No 2 | milestone | 0d | 2025-09-15 | 2025-09-15 | 439 |  |  | 61d | 0d | start no earlier than 2025-09-15 | SKAPHE |  |  | 0% | 0% |  |
| 441 | 1.9.6.3.4 | Realizar aprobación entrega No 2 |  | 2d | 2025-09-15 | 2025-09-16 | 440 |  |  | 61d |  |  | SNR | 16h |  | 0% | 0% |  |

Notes:
- 419: 82 libros
- 421: 82 libros
- 438: 117 libros
- 440: 118 libros

| ID | WBS | Task | Type | Duration | Start | Finish | Predecessors | Total slack | Free slack | Constraint | Resources | Work | %Planeado | %Retraso |
| --- | --- | --- | --- | --- | --- | --- | --- | --- | --- | --- | --- | --- | --- | --- |
| 442 | 1.9.7 | **Proceso de Digitalizacion** |  | 23d | 2025-09-15 | 2025-10-16 |  | 23d |  |  | SKAPHE | 480h | 0% | 0% |
| 443 | 1.9.7.1 | Actividades de digitalización |  | 21d | 2025-09-15 | 2025-10-14 | 439 | 23d | 0d | start no earlier than 2025-09-15 | SKAPHE | 168h | 0% | 0% |
| 444 | 1.9.7.2 | **Realizar entrega de libros** |  | 12d | 2025-09-29 | 2025-10-16 |  | 23d |  |  | SKAPHE | 128h | 0% | 0% |
| 445 | 1.9.7.2.1 | Entrega libros No 1 | milestone | 0d | 2025-09-29 | 2025-09-29 | 443SS+11d | 23d | 0d | start no earlier than 2025-09-26 | SKAPHE |  | 0% | 0% |
| 446 | 1.9.7.2.2 | Realizar aprobación entrega No 1 |  | 2d | 2025-09-30 | 2025-10-01 | 445 | 23d | 0d | start no earlier than 2025-09-30 | SNR | 16h | 0% | 0% |
| 447 | 1.9.7.2.3 | Entrega libros No 2 | milestone | 0d | 2025-10-15 | 2025-10-15 | 443 | 40d | 0d | start no earlier than 2025-10-15 | SKAPHE |  | 0% | 0% |
| 448 | 1.9.7.2.4 | Realizar aprobación entrega No 2 |  | 2d | 2025-10-15 | 2025-10-16 | 447 | 40d |  |  | SNR | 16h | 0% | 0% |
| 449 | 1.9.8 | **Proceso de Descripcion e Indexacion** |  | 20d | 2025-10-02 | 2025-10-30 |  | 23d |  |  | SKAPHE | 440h | 0% | 0% |
| 450 | 1.9.8.1 | Actividades de descripción e indexación |  | 18d | 2025-10-02 | 2025-10-28 | 446 | 23d | 2d | start no earlier than 2025-10-02 | SKAPHE | 144h | 0% | 0% |
| 451 | 1.9.8.2 | **Realizar entrega de libros** |  | 13d | 2025-10-14 | 2025-10-30 |  | 21d |  |  | SKAPHE | 136h | 0% | 0% |
| 452 | 1.9.8.2.1 | Entrega libros No 1 | milestone | 0d | 2025-10-14 | 2025-10-14 | 450SS+5d | 21d | 0d | start no earlier than 2025-10-14 | SKAPHE |  | 0% | 0% |
| 453 | 1.9.8.2.2 | Realizar aprobación entrega No 1 |  | 2d | 2025-10-14 | 2025-10-15 | 452 | 21d | 0d |  | SNR | 16h | 0% | 0% |
| 454 | 1.9.8.2.3 | Entrega libros No 2 | milestone | 0d | 2025-10-29 | 2025-10-29 |  | 30d | 0d | start no earlier than 2025-10-29 | SKAPHE |  | 0% | 0% |
| 455 | 1.9.8.2.4 | Realizar aprobación entrega No 2 |  | 2d | 2025-10-29 | 2025-10-30 | 454 | 30d |  |  | SNR | 16h | 0% | 0% |
| 456 | 1.9.9 | **Proceso de Realmacenamiento en Unidades de Conservacion** |  | 20d | 2025-10-02 | 2025-10-30 |  | 30d |  |  | SKAPHE | 432h | 0% | 0% |
| 457 | 1.9.9.1 | Actividades de realmacenamiento |  | 18d | 2025-10-02 | 2025-10-28 | 446 | 32d | 0d | start no earlier than 2025-10-02 | SKAPHE | 144h | 0% | 0% |
| 458 | 1.9.9.2 | **Realizar entrega de libros** |  | 12d | 2025-10-15 | 2025-10-30 |  | 30d |  |  | SKAPHE | 128h | 0% | 0% |
| 459 | 1.9.9.2.1 | Entrega libros No 1 | milestone | 0d | 2025-10-15 | 2025-10-15 | 457SS+8d | 40d | 0d | start no earlier than 2025-10-15 | SKAPHE |  | 0% | 0% |
| 460 | 1.9.9.2.2 | Realizar aprobación entrega No 1 |  | 2d | 2025-10-15 | 2025-10-16 | 459 | 40d |  |  | SNR | 16h | 0% | 0% |
| 461 | 1.9.9.2.3 | Entrega libros No 2 | milestone | 0d | 2025-10-29 | 2025-10-29 |  | 29d | 0d | start no earlier than 2025-10-29 | SKAPHE |  | 0% | 0% |
| 462 | 1.9.9.2.4 | Realizar aprobación entrega No 2 |  | 2d | 2025-10-29 | 2025-10-30 | 461 | 29d | 0d |  | SNR | 16h | 0% | 0% |
| 463 | 1.9.10 | **Proceso de discos Duros** |  | 22d | 2025-10-16 | 2025-11-18 |  | 19d |  |  | SKAPHE | 456h | 0% | 0% |
| 464 | 1.9.10.1 | Copiado de discos duros |  | 20d | 2025-10-16 | 2025-11-13 | 453 | 21d | 1d | start no earlier than 2025-10-16 | SKAPHE | 160h | 0% | 0% |
| 465 | 1.9.10.2 | **Entrega de discos duros** |  | 11d | 2025-10-31 | 2025-11-18 |  | 19d |  |  | SKAPHE | 120h | 0% | 0% |
| 466 | 1.9.10.2.1 | Entrega libros No 1 | milestone | 0d | 2025-10-31 | 2025-10-31 | 464SS+10d | 28d | 0d | start no earlier than 2025-10-31 | SKAPHE |  | 0% | 0% |
| 467 | 1.9.10.2.2 | Realizar aprobación entrega No 1 |  | 2d | 2025-10-31 | 2025-11-04 | 466 | 28d |  | start no earlier than 2025-10-31 | SNR | 16h | 0% | 0% |
| 468 | 1.9.10.2.3 | Entrega libros No 2 | milestone | 0d | 2025-11-14 | 2025-11-14 |  | 19d | 0d | start no earlier than 2025-11-14 | SKAPHE |  | 0% | 0% |
| 469 | 1.9.10.2.4 | Realizar aprobación entrega No 2 |  | 2d | 2025-11-14 | 2025-11-18 | 468 | 19d |  | finish no earlier than 2025-04-11 | SNR | 16h | 0% | 0% |
| 470 | 1.9.11 | Traslado de Libros del Antiguo Sistema Registral al Archivo Central |  | 1d | 2025-10-31 | 2025-10-31 | 462 | 29d |  | start no earlier than 2025-10-31 | SKAPHE | 8h | 0% | 0% |
| 471 | 1.9.12 | Intervencion tecnica por Demanda /Prestamo de Unidades documentales en porceos de Digitalizacion |  | 76d | 2025-07-04 | 2025-10-22 | 432SS | 36d | 0d | start no earlier than 2025-07-04 | SKAPHE | 608h | 0% | 0% |
| 472 | 1.9.13 | Control Calidad Tranversal procesos | milestone | 76d | 2025-07-04 | 2025-10-22 | 471SS | 36d |  | start no earlier than 2025-03-21 | SKAPHE | 608h | 0% | 0% |
| 473 | 1.10 | 1 ENTREGA LIBROS | milestone | 0d | 2025-06-17 | 2025-06-17 |  | 125d |  | start no earlier than 2025-06-17 | SKAPHE |  | 0% | 0% |
| 474 | 1.11 | 2 ENTREGA LIBROS | milestone | 0d | 2025-07-17 | 2025-07-17 |  | 103d |  | start no earlier than 2025-07-17 | SKAPHE |  | 0% | 0% |
| 475 | 1.12 | 3 ENTREGA LIBROS | milestone | 0d | 2025-08-17 | 2025-08-17 |  | 82d |  | start no earlier than 2025-08-17 | SKAPHE |  | 0% | 0% |
| 476 | 1.13 | 4 ENTREGA LIBROS | milestone | 0d | 2025-09-17 | 2025-09-17 |  | 61d |  | start no earlier than 2025-09-17 | SKAPHE |  | 0% | 0% |
| 477 | 1.14 | 5 ENTREGA LIBROS | milestone | 0d | 2025-10-17 | 2025-10-17 |  | 40d |  | start no earlier than 2025-10-17 | SKAPHE |  | 0% | 0% |
| 478 | 1.15 | 6 ENTREGA LIBROS | milestone | 0d | 2025-11-17 | 2025-11-17 |  | 20d |  | start no earlier than 2025-11-17 | SKAPHE |  | 0% | 0% |
| 479 | 1.16 | 7 ENTREGA LIBROS | milestone | 0d | 2025-12-17 | 2025-12-17 |  | 0d |  | start no earlier than 2025-12-17 | SKAPHE |  | 0% | 0% |

Notes:
- 445: 117 libros
- 447: 118 libros
- 452: 117 libros
- 454: 118 libros
- 459: 117 libros
- 461: 118 libros
- 466: 82 libros
- 468: 82 libros
- 472: Entrega Informe
- 473: Yopal 53/Rioacha 235 /Cartago 118
- 474: Sabanalarga 348 / Cartago 48
- 475: Carmen de Bolivar 229 / Cerete 100 / Cartago 67
- 476: Cerete 226 / Cartago 170
- 477: Sahagun 368 / Cartago 28
- 478: Magangue 164 / Cartago 232
- 479: Monpox 235 / Cartago 60 / Adicionales 110
